# Project Name

Schedule from MS Project, 2023-10-12 to 2026-03-25, status date 2024-01-31, costs in RM.

## Calendars

- 6 Working Days: Mon-Sat 08:00-12:00, 13:00-17:00; Sun off. Exceptions (off unless hours are given): 2023-05-01 to 2024-05-01 (Labour Day 2023, recurring), 2023-08-31 to 2024-08-31 (Malaysia's National Day, recurring), 2023-09-16 to 2024-09-16 (Malaysia Day, recurring), 2023-11-12 (Deepavali), 2023-12-11 (Sultan Selangor's Birthday 2023), 2023-12-25 to 2024-12-25 (Christmas, recurring), 2024-01-01 (New Year), 2024-02-11 to 2026-02-10 (Chinese New Year, recurring), 2024-04-10 to 2024-04-11 (Hari Raya Aidilfitri 2024), 2024-05-22 (Wesak Day 2024), 2024-06-03 (Aong's Birthday 2024), 2024-06-17 (Hari Raya Haji 2024), 2024-10-31 (Deepavali 2024), 2024-12-11 (Sultan Selangor's Birthday 2024), 2025-01-29 to 2025-01-30 (Chinese New Year 2025), 2025-03-31 to 2025-04-01 (Hari Raya Aidilfitri 2025), 2025-05-12 (Wesak Day 2025).

## Resources

| Resource | Unit |
| --- | --- |
| Pile (Spun Pile) | nos |
| Steel Bar | kg |
| BRC A8 | pieces |
| Concrete G35 | m3 |
| Concrete G45 | m3 |
| Concrete G60 | m3 |
| Concrete G30 | m3 |
| Pile (RC Pile) | nos |

## Schedule

| ID | WBS | Task | Type | Duration | Start | Finish | Baseline start | Baseline finish | Baseline duration | Total slack | Constraint | Cost | %Planned | Target Start | Target Finsh |
| --- | --- | --- | --- | --- | --- | --- | --- | --- | --- | --- | --- | --- | --- | --- | --- |
| 1 | 1 | **Project Name** |  | 747d | 2023-10-12 | 2026-03-25 | 2024-01-01 | 2025-01-01 | 0d | 0d |  | 110 | 0% | 01/01/2024 | 01/01/2025 |
| 2 | 1.1 | **Design, Award, Submission & Procurement Stage** |  | 460d | 2024-01-02 | 2025-07-10 |  |  |  | 0d |  |  | 0% |  |  |
| 3 | 1.1.1 | **Design / Drawing Stage** |  | 90d | 2024-01-02 | 2024-04-17 |  |  |  | 0d |  |  | 0% |  |  |
| 4 | 1.1.1.1 | **Sub-structure Construction Drawing** |  | 30d | 2024-01-02 | 2024-02-05 |  |  |  | 0d |  |  | 0% |  |  |
| 5 | 1.1.1.1.1 | Piling Drawing | milestone | 28d | 2024-01-02 | 2024-02-02 | 2024-01-02 | 2024-02-02 | 28d | 0d |  |  | 0% |  |  |
| 6 | 1.1.1.1.2 | Pile Cap Drawing | milestone | 30d | 2024-01-02 | 2024-02-05 | 2024-01-02 | 2024-02-05 | 30d | 0d |  |  | 0% |  |  |
| 7 | 1.1.1.1.3 | Ground Beam Drawing | milestone | 30d | 2024-01-02 | 2024-02-05 | 2024-01-02 | 2024-02-05 | 30d | 0d | start no earlier than 2024-01-02 |  | 0% |  |  |
| 8 | 1.1.1.2 | **Superstructure Construction Drawing** |  | 90d | 2024-01-02 | 2024-04-17 |  |  |  | 0d |  |  | 0% |  |  |
| 9 | 1.1.1.2.1 | Structure Site Plan | milestone | 30d | 2024-01-02 | 2024-02-05 | 2024-01-02 | 2024-02-05 | 30d | 0d |  |  | 0% |  |  |
| 10 | 1.1.1.2.2 | Typical Slab & Beam Details Drawing | milestone | 30d | 2024-01-02 | 2024-02-05 | 2024-01-02 | 2024-02-05 | 30d | 0d |  |  | 0% |  |  |
| 11 | 1.1.1.2.3 | Typical Column & Wall Details Drawing | milestone | 30d | 2024-01-02 | 2024-02-05 | 2024-01-02 | 2024-02-05 | 30d | 0d |  |  | 0% |  |  |
| 12 | 1.1.1.2.4 | Typical Mezzanine Slab & Beam Details Drawing | milestone | 30d | 2024-01-02 | 2024-02-05 | 2024-01-02 | 2024-02-05 | 30d | 0d |  |  | 0% |  |  |
| 13 | 1.1.1.2.5 | Typical Mezzanine Column & Wall Details Drawing | milestone | 30d | 2024-01-02 | 2024-02-05 | 2024-01-02 | 2024-02-05 | 30d | 0d |  |  | 0% |  |  |
| 14 | 1.1.1.2.6 | Post Tension Drawing | milestone | 90d | 2024-01-02 | 2024-04-17 | 2024-01-02 | 2024-04-17 | 90d | 0d |  |  | 0% |  |  |
| 15 | 1.1.1.2.7 | Roof Trussess Drawing | milestone | 30d | 2024-01-02 | 2024-02-05 | 2024-01-02 | 2024-02-05 | 30d | 0d |  |  | 0% |  |  |
| 16 | 1.1.1.2.8 | TNB, Electrical Room, Management Room & Water Tank Details Drawing | milestone | 30d | 2024-01-02 | 2024-02-05 | 2024-01-02 | 2024-02-05 | 30d | 0d |  |  | 0% |  |  |
| 17 | 1.1.1.2.9 | Guard House Details Drawing | milestone | 30d | 2024-01-02 | 2024-02-05 | 2024-01-02 | 2024-02-05 | 30d | 0d |  |  | 0% |  |  |
| 18 | 1.1.1.3 | **Architecture Construction Drawing** |  | 30d | 2024-01-02 | 2024-02-05 |  |  |  | 0d |  |  | 0% |  |  |
| 19 | 1.1.1.3.1 | Architecture Site Plan | milestone | 28d | 2024-01-02 | 2024-02-02 | 2024-01-02 | 2024-02-02 | 28d | 0d |  |  | 0% |  |  |
| 20 | 1.1.1.3.2 | Typical Warehouse Details Drawing | milestone | 30d | 2024-01-02 | 2024-02-05 | 2024-01-02 | 2024-02-05 | 30d | 0d |  |  | 0% |  |  |
| 21 | 1.1.1.3.3 | Typical Mezzanine Warehouse & Office Details Drawing | milestone | 30d | 2024-01-02 | 2024-02-05 | 2024-01-02 | 2024-02-05 | 30d | 0d |  |  | 0% |  |  |
| 22 | 1.1.1.3.4 | Staircase Details Drawing | milestone | 30d | 2024-01-02 | 2024-02-05 | 2024-01-02 | 2024-02-05 | 30d | 0d |  |  | 0% |  |  |
| 23 | 1.1.1.3.5 | TNB, Electrical Room & Management Room Details Drawing | milestone | 30d | 2024-01-02 | 2024-02-05 | 2024-01-02 | 2024-02-05 | 30d | 0d |  |  | 0% |  |  |
| 24 | 1.1.1.3.6 | Guard House Details Drawing | milestone | 30d | 2024-01-02 | 2024-02-05 | 2024-01-02 | 2024-02-05 | 30d | 0d |  |  | 0% |  |  |
| 25 | 1.1.1.3.7 | RWDP Drawing | milestone | 30d | 2024-01-02 | 2024-02-05 | 2024-01-02 | 2024-02-05 | 30d | 0d |  |  | 0% |  |  |
| 26 | 1.1.1.3.8 | Door, Window Glazing Details Drawing | milestone | 30d | 2024-01-02 | 2024-02-05 | 2024-01-02 | 2024-02-05 | 30d | 0d | start no earlier than 2024-01-02 |  | 0% |  |  |
| 27 | 1.1.1.3.9 | Tiles & Ceiling Details Drawing | milestone | 30d | 2024-01-02 | 2024-02-05 | 2024-01-02 | 2024-02-05 | 30d | 0d | start no earlier than 2024-01-02 |  | 0% |  |  |
| 28 | 1.1.1.3.10 | Railing & Mild Steel Details Works | milestone | 30d | 2024-01-02 | 2024-02-05 | 2024-01-02 | 2024-02-05 | 30d | 0d |  |  | 0% |  |  |
| 29 | 1.1.1.3.11 | Toilet Details Drawing | milestone | 30d | 2024-01-02 | 2024-02-05 | 2024-01-02 | 2024-02-05 | 30d | 0d |  |  | 0% |  |  |
| 30 | 1.1.1.3.12 | Male & Female Toilet & Prayer Room Details Drawing | milestone | 30d | 2024-01-02 | 2024-02-05 | 2024-01-02 | 2024-02-05 | 30d | 0d |  |  | 0% |  |  |
| 31 | 1.1.1.3.13 | Lift Lobby Details Drawing | milestone | 30d | 2024-01-02 | 2024-02-05 | 2024-01-02 | 2024-02-05 | 30d | 0d |  |  | 0% |  |  |
| 32 | 1.1.1.3.14 | Refuse Centre Drawing | milestone | 30d | 2024-01-02 | 2024-02-05 | 2024-01-02 | 2024-02-05 | 30d | 0d |  |  | 0% |  |  |
| 33 | 1.1.1.3.15 | Management Room Details Drawing | milestone | 30d | 2024-01-02 | 2024-02-05 | 2024-01-02 | 2024-02-05 | 30d | 0d |  |  | 0% |  |  |
| 34 | 1.1.1.3.16 | Landscape Drawing | milestone | 30d | 2024-01-02 | 2024-02-05 | 2024-01-02 | 2024-02-05 | 30d | 0d |  |  | 0% |  |  |
| 35 | 1.1.1.3.17 | Car Park Road Marking Details Drawing | milestone | 30d | 2024-01-02 | 2024-02-05 | 2024-01-02 | 2024-02-05 | 30d | 0d |  |  | 0% |  |  |

| ID | WBS | Task | Type | Duration | Start | Finish | Baseline start | Baseline finish | Baseline duration | Total slack | %Planned |
| --- | --- | --- | --- | --- | --- | --- | --- | --- | --- | --- | --- |
| 36 | 1.1.1.4 | **M&E Construction Drawing** |  | 31d | 2024-01-02 | 2024-02-06 |  |  |  | 0d | 0% |
| 37 | 1.1.1.4.1 | Electrical Services | milestone | 31d | 2024-01-02 | 2024-02-06 | 2024-01-02 | 2024-02-06 | 31d | 0d | 0% |
| 38 | 1.1.1.4.2 | ELV Services | milestone | 31d | 2024-01-02 | 2024-02-06 | 2024-01-02 | 2024-02-06 | 31d | 0d | 0% |
| 39 | 1.1.1.4.3 | Cold Water & Sanitary Plumbing Services | milestone | 31d | 2024-01-02 | 2024-02-06 | 2024-01-02 | 2024-02-06 | 31d | 0d | 0% |
| 40 | 1.1.1.4.4 | ACMV Services | milestone | 31d | 2024-01-02 | 2024-02-06 | 2024-01-02 | 2024-02-06 | 31d | 0d | 0% |
| 41 | 1.1.1.4.5 | Fire Protection Services | milestone | 31d | 2024-01-02 | 2024-02-06 | 2024-01-02 | 2024-02-06 | 31d | 0d | 0% |
| 42 | 1.1.1.4.6 | Lift & Goods Hoist Services | milestone | 31d | 2024-01-02 | 2024-02-06 | 2024-01-02 | 2024-02-06 | 31d | 0d | 0% |
| 43 | 1.1.1.5 | **Insfrastructure Construction Drawing** |  | 30d | 2024-01-02 | 2024-02-05 |  |  |  | 0d | 0% |
| 44 | 1.1.1.5.1 | Road & Drainage Structure Drawing | milestone | 30d | 2024-01-02 | 2024-02-05 | 2024-01-02 | 2024-02-05 | 30d | 0d | 0% |
| 45 | 1.1.1.5.2 | Fencing & Gate Details Architecture Drawing | milestone | 30d | 2024-01-02 | 2024-02-05 | 2024-01-02 | 2024-02-05 | 30d | 0d | 0% |
| 46 | 1.1.1.5.3 | Sewerage Drawing | milestone | 30d | 2024-01-02 | 2024-02-05 | 2024-01-02 | 2024-02-05 | 30d | 0d | 0% |
| 47 | 1.1.1.5.4 | Water Reticulation Drawing | milestone | 30d | 2024-01-02 | 2024-02-05 | 2024-01-02 | 2024-02-05 | 30d | 0d | 0% |
| 48 | 1.1.2 | **Awarding Stage** |  | 31d | 2024-01-02 | 2024-02-06 |  |  |  | 0d | 0% |
| 49 | 1.1.2.1 | Earthwork Contractor | milestone | 31d | 2024-01-02 | 2024-02-06 | 2024-01-02 | 2024-02-06 | 31d | 0d | 0% |
| 50 | 1.1.2.2 | Piling Contractor | milestone | 28d | 2024-01-02 | 2024-02-02 | 2024-01-02 | 2024-02-02 | 28d | 0d | 0% |
| 51 | 1.1.2.3 | Anti-Termite Contractor | milestone | 30d | 2024-01-02 | 2024-02-05 | 2024-01-02 | 2024-02-05 | 30d | 0d | 0% |
| 52 | 1.1.2.4 | Post Tension Contractor | milestone | 30d | 2024-01-02 | 2024-02-05 | 2024-01-02 | 2024-02-05 | 30d | 0d | 0% |
| 53 | 1.1.2.5 | RC Structure Contractor | milestone | 30d | 2024-01-02 | 2024-02-05 | 2024-01-02 | 2024-02-05 | 30d | 0d | 0% |
| 54 | 1.1.2.6 | Floor Hardener Contractor | milestone | 30d | 2024-01-02 | 2024-02-05 | 2024-01-02 | 2024-02-05 | 30d | 0d | 0% |
| 55 | 1.1.2.7 | Waterproofing Contractor | milestone | 30d | 2024-01-02 | 2024-02-05 | 2024-01-02 | 2024-02-05 | 30d | 0d | 0% |
| 56 | 1.1.2.8 | Roof Steel Structure Contractor | milestone | 30d | 2024-01-02 | 2024-02-05 | 2024-01-02 | 2024-02-05 | 30d | 0d | 0% |
| 57 | 1.1.2.9 | Metal Deck Contractor | milestone | 30d | 2024-01-02 | 2024-02-05 | 2024-01-02 | 2024-02-05 | 30d | 0d | 0% |
| 58 | 1.1.2.10 | Brick, Skim Coat, Plaster, Door Frame Contractor | milestone | 30d | 2024-01-02 | 2024-02-05 | 2024-01-02 | 2024-02-05 | 30d | 0d | 0% |
| 59 | 1.1.2.11 | Facada Cladding + Roof Covering Contractor | milestone | 30d | 2024-01-02 | 2024-02-05 | 2024-01-02 | 2024-02-05 | 30d | 0d | 0% |
| 60 | 1.1.2.12 | Aluminium Window Contractor | milestone | 30d | 2024-01-02 | 2024-02-05 | 2024-01-02 | 2024-02-05 | 30d | 0d | 0% |
| 61 | 1.1.2.13 | Ceiling Contractor | milestone | 30d | 2024-01-02 | 2024-02-05 | 2024-01-02 | 2024-02-05 | 30d | 0d | 0% |
| 62 | 1.1.2.14 | Tiles Contractor | milestone | 30d | 2024-01-02 | 2024-02-05 | 2024-01-02 | 2024-02-05 | 30d | 0d | 0% |
| 63 | 1.1.2.15 | Paint Contractor | milestone | 30d | 2024-01-02 | 2024-02-05 | 2024-01-02 | 2024-02-05 | 30d | 0d | 0% |
| 64 | 1.1.2.16 | Door Leaf Installer | milestone | 30d | 2024-01-02 | 2024-02-05 | 2024-01-02 | 2024-02-05 | 30d | 0d | 0% |
| 65 | 1.1.2.17 | Toilet Cubicle Installer | milestone | 30d | 2024-01-02 | 2024-02-05 | 2024-01-02 | 2024-02-05 | 30d | 0d | 0% |
| 66 | 1.1.2.18 | RWDP Contractor | milestone | 30d | 2024-01-02 | 2024-02-05 | 2024-01-02 | 2024-02-05 | 30d | 0d | 0% |
| 67 | 1.1.2.19 | Electrical Services Contractor | milestone | 30d | 2024-01-02 | 2024-02-05 | 2024-01-02 | 2024-02-05 | 30d | 0d | 0% |
| 68 | 1.1.2.20 | ELV Services Contractor | milestone | 30d | 2024-01-02 | 2024-02-05 | 2024-01-02 | 2024-02-05 | 30d | 0d | 0% |
| 69 | 1.1.2.21 | Cold Water & Sanitary Plumbing Services Contractor | milestone | 30d | 2024-01-02 | 2024-02-05 | 2024-01-02 | 2024-02-05 | 30d | 0d | 0% |
| 70 | 1.1.2.22 | ACMV Servises Contractor | milestone | 30d | 2024-01-02 | 2024-02-05 | 2024-01-02 | 2024-02-05 | 30d | 0d | 0% |
| 71 | 1.1.2.23 | Fire Protection Services Contractor | milestone | 30d | 2024-01-02 | 2024-02-05 | 2024-01-02 | 2024-02-05 | 30d | 0d | 0% |
| 72 | 1.1.2.24 | Lift & Goods Hoist Services Contractor | milestone | 30d | 2024-01-02 | 2024-02-05 | 2024-01-02 | 2024-02-05 | 30d | 0d | 0% |
| 73 | 1.1.2.25 | Road & Drainage Contractor | milestone | 30d | 2024-01-02 | 2024-02-05 | 2024-01-02 | 2024-02-05 | 30d | 0d | 0% |
| 74 | 1.1.2.26 | Sewerage Contractor | milestone | 30d | 2024-01-02 | 2024-02-05 | 2024-01-02 | 2024-02-05 | 30d | 0d | 0% |
| 75 | 1.1.2.27 | Water Reticulation Contractor | milestone | 30d | 2024-01-02 | 2024-02-05 | 2024-01-02 | 2024-02-05 | 30d | 0d | 0% |
| 76 | 1.1.2.28 | Fencing and Gate Contractor | milestone | 30d | 2024-01-02 | 2024-02-05 | 2024-01-02 | 2024-02-05 | 30d | 0d | 0% |

| ID | WBS | Task | Type | Duration | Start | Finish | Baseline start | Baseline finish | Baseline duration | Total slack | %Planned |
| --- | --- | --- | --- | --- | --- | --- | --- | --- | --- | --- | --- |
| 77 | 1.1.3 | **Shop Drawing, Material & Method Statement Stage** |  | 90d | 2024-01-02 | 2024-04-17 |  |  |  | 0d | 0% |
| 78 | 1.1.3.1 | **Structure Shop Drawing, Material & Method Statement** |  | 60d | 2024-01-02 | 2024-03-11 |  |  |  | 0d | 0% |
| 79 | 1.1.3.1.1 | Piling |  | 60d | 2024-01-02 | 2024-03-11 | 2024-01-02 | 2024-03-11 | 60d | 0d | 0% |
| 80 | 1.1.3.1.2 | Post Tension | milestone | 60d | 2024-01-02 | 2024-03-11 | 2024-01-02 | 2024-03-11 | 60d | 0d | 0% |
| 81 | 1.1.3.1.3 | Roof Truss | milestone | 60d | 2024-01-02 | 2024-03-11 | 2024-01-02 | 2024-03-11 | 60d | 0d | 0% |
| 82 | 1.1.3.2 | **Architecture Shop Drawing, Material & Method Statement** |  | 60d | 2024-01-02 | 2024-03-11 |  |  |  | 0d | 0% |
| 83 | 1.1.3.2.1 | Metal Deck |  | 60d | 2024-01-02 | 2024-03-11 | 2024-01-02 | 2024-03-11 | 60d | 0d | 0% |
| 84 | 1.1.3.2.2 | Wall Panel Cladding |  | 60d | 2024-01-02 | 2024-03-11 | 2024-01-02 | 2024-03-11 | 60d | 0d | 0% |
| 85 | 1.1.3.2.3 | Door | milestone | 60d | 2024-01-02 | 2024-03-11 | 2024-01-02 | 2024-03-11 | 60d | 0d | 0% |
| 86 | 1.1.3.2.4 | Window | milestone | 60d | 2024-01-02 | 2024-03-11 | 2024-01-02 | 2024-03-11 | 60d | 0d | 0% |
| 87 | 1.1.3.2.5 | Waterproof | milestone | 60d | 2024-01-02 | 2024-03-11 | 2024-01-02 | 2024-03-11 | 60d | 0d | 0% |
| 88 | 1.1.3.2.6 | Tiling | milestone | 60d | 2024-01-02 | 2024-03-11 | 2024-01-02 | 2024-03-11 | 60d | 0d | 0% |
| 89 | 1.1.3.2.7 | Ceiling | milestone | 60d | 2024-01-02 | 2024-03-11 | 2024-01-02 | 2024-03-11 | 60d | 0d | 0% |
| 90 | 1.1.3.2.8 | Railing | milestone | 60d | 2024-01-02 | 2024-03-11 | 2024-01-02 | 2024-03-11 | 60d | 0d | 0% |
| 91 | 1.1.3.2.9 | Toilet Cubicle | milestone | 60d | 2024-01-02 | 2024-03-11 | 2024-01-02 | 2024-03-11 | 60d | 0d | 0% |
| 92 | 1.1.3.2.10 | Painting | milestone | 60d | 2024-01-02 | 2024-03-11 | 2024-01-02 | 2024-03-11 | 60d | 0d | 0% |
| 93 | 1.1.3.2.11 | Car Park Marking / Signage | milestone | 60d | 2024-01-02 | 2024-03-11 | 2024-01-02 | 2024-03-11 | 60d | 0d | 0% |
| 94 | 1.1.3.3 | **M&E Shop Drawing, Material & Method Statement** |  | 90d | 2024-01-02 | 2024-04-17 |  |  |  | 0d | 0% |
| 95 | 1.1.3.3.1 | Electrical & ELV Services | milestone | 90d | 2024-01-02 | 2024-04-17 | 2024-01-02 | 2024-04-17 | 90d | 0d | 0% |
| 96 | 1.1.3.3.2 | Plumbing & Sanitary Services | milestone | 90d | 2024-01-02 | 2024-04-17 | 2024-01-02 | 2024-04-17 | 90d | 0d | 0% |
| 97 | 1.1.3.3.3 | ACMV Services | milestone | 90d | 2024-01-02 | 2024-04-17 | 2024-01-02 | 2024-04-17 | 90d | 0d | 0% |
| 98 | 1.1.3.3.4 | Fire Protection Services | milestone | 90d | 2024-01-02 | 2024-04-17 | 2024-01-02 | 2024-04-17 | 90d | 0d | 0% |
| 99 | 1.1.3.3.5 | Lift & Goods Hoist Services | milestone | 90d | 2024-01-02 | 2024-04-17 | 2024-01-02 | 2024-04-17 | 90d | 0d | 0% |
| 100 | 1.1.4 | **Procurement Stage** |  | 460d | 2024-01-02 | 2025-07-10 |  |  |  | 0d | 0% |
| 101 | 1.1.4.1 | **Structural Procurement** |  | 460d | 2024-01-02 | 2025-07-10 |  |  |  | 0d | 0% |
| 102 | 1.1.4.1.1 | **Piling Works** |  | 170d | 2024-01-02 | 2024-07-24 |  |  |  | 0d | 0% |
| 103 | 1.1.4.1.1.1 | Spun Pile | milestone | 170d | 2024-01-02 | 2024-07-24 | 2024-01-02 | 2024-07-24 | 170d | 0d | 0% |
| 104 | 1.1.4.1.1.2 | RC Pile | milestone | 170d | 2024-01-02 | 2024-07-24 | 2024-01-02 | 2024-07-24 | 170d | 0d | 0% |

| ID | WBS | Task | Type | Duration | Start | Finish | Baseline start | Baseline finish | Baseline duration | Total slack | %Planned |
| --- | --- | --- | --- | --- | --- | --- | --- | --- | --- | --- | --- |
| 105 | 1.1.4.1.2 | **Reinforcement Concrete Work** |  | 460d | 2024-01-02 | 2025-07-10 |  |  |  | 0d | 0% |
| 106 | 1.1.4.1.2.1 | Steel Bar Work | milestone | 460d | 2024-01-02 | 2025-07-10 | 2024-01-02 | 2025-07-10 | 460d | 0d | 0% |
| 107 | 1.1.4.1.2.2 | BRC | milestone | 460d | 2024-01-02 | 2025-07-10 | 2024-01-02 | 2025-07-10 | 460d | 0d | 0% |
| 108 | 1.1.4.1.3 | **Post Tension Works** |  | 380d | 2024-01-02 | 2025-04-07 |  |  |  | 0d | 0% |
| 109 | 1.1.4.1.3.1 | PT Strands | milestone | 380d | 2024-01-02 | 2025-04-07 | 2024-01-02 | 2025-04-07 | 380d | 0d | 0% |
| 110 | 1.1.4.1.4 | **Roof Truss & Covering Works** |  | 200d | 2024-01-02 | 2024-08-28 |  |  |  | 0d | 0% |
| 111 | 1.1.4.1.4.1 | Roof Trusses | milestone | 120d | 2024-01-02 | 2024-05-24 | 2024-01-02 | 2024-05-24 | 120d | 0d | 0% |
| 112 | 1.1.4.1.4.2 | Metal Deck | milestone | 200d | 2024-01-02 | 2024-08-28 | 2024-01-02 | 2024-08-28 | 200d | 0d | 0% |
| 113 | 1.1.4.2 | **Architecture Procurement** |  | 400d | 2024-01-02 | 2025-04-30 |  |  |  | 0d | 0% |
| 114 | 1.1.4.2.1 | **Wall Panel Cladding** |  | 100d | 2024-01-02 | 2024-04-29 |  |  |  | 0d | 0% |
| 115 | 1.1.4.2.1.1 | Metal Cladding | milestone | 100d | 2024-01-02 | 2024-04-29 | 2024-01-02 | 2024-04-29 | 100d | 0d | 0% |
| 116 | 1.1.4.2.1.2 | FRP Translucent Panel | milestone | 100d | 2024-01-02 | 2024-04-29 | 2024-01-02 | 2024-04-29 | 100d | 0d | 0% |
| 117 | 1.1.4.2.1.3 | Bird Neeting | milestone | 100d | 2024-01-02 | 2024-04-29 | 2024-01-02 | 2024-04-29 | 100d | 0d | 0% |
| 118 | 1.1.4.2.2 | **Rain Water Down Pipe** |  | 400d | 2024-01-02 | 2025-04-30 |  |  |  | 0d | 0% |
| 119 | 1.1.4.2.2.1 | UPVC Pipe | milestone | 400d | 2024-01-02 | 2025-04-30 | 2024-01-02 | 2025-04-30 | 400d | 0d | 0% |
| 120 | 1.1.4.2.2.2 | Zincalume Gutter | milestone | 300d | 2024-01-02 | 2024-12-28 | 2024-01-02 | 2024-12-28 | 300d | 0d | 0% |
| 121 | 1.1.4.2.3 | **Door Frame, Leaf & Ironmongeries** |  | 370d | 2024-01-02 | 2025-03-24 |  |  |  | 0d | 0% |
| 122 | 1.1.4.2.3.1 | **Door Frame** |  | 370d | 2024-01-02 | 2025-03-24 |  |  |  | 0d | 0% |
| 123 | 1.1.4.2.3.1.1 | Fire Rated Door Frame | milestone | 370d | 2024-01-02 | 2025-03-24 | 2024-01-02 | 2025-03-24 | 370d | 0d | 0% |
| 124 | 1.1.4.2.3.1.2 | Timber Door Frame | milestone | 370d | 2024-01-02 | 2025-03-24 | 2024-01-02 | 2025-03-24 | 370d | 0d | 0% |
| 125 | 1.1.4.2.3.1.3 | Louvres Door Frame | milestone | 370d | 2024-01-02 | 2025-03-24 | 2024-01-02 | 2025-03-24 | 370d | 0d | 0% |
| 126 | 1.1.4.2.3.1.4 | Metal Door Frame | milestone | 370d | 2024-01-02 | 2025-03-24 | 2024-01-02 | 2025-03-24 | 370d | 0d | 0% |
| 127 | 1.1.4.2.3.1.5 | Glass Door Frame | milestone | 30d | 2024-01-02 | 2024-02-05 | 2024-01-02 | 2024-02-05 | 30d | 0d | 0% |
| 128 | 1.1.4.2.3.2 | Door Leaf & Ironmongeries |  | 100d | 2024-01-02 | 2024-04-29 | 2024-01-02 | 2024-04-29 | 100d | 0d | 0% |

| ID | WBS | Task | Type | Duration | Start | Finish | Baseline start | Baseline finish | Baseline duration | Total slack | %Planned |
| --- | --- | --- | --- | --- | --- | --- | --- | --- | --- | --- | --- |
| 129 | 1.1.4.2.4 | **Tiles** |  | 350d | 2024-01-02 | 2025-02-28 |  |  |  | 0d | 0% |
| 130 | 1.1.4.2.4.1 | Vinyl Tiles | milestone | 350d | 2024-01-02 | 2025-02-28 | 2024-01-02 | 2025-02-28 | 350d | 0d | 0% |
| 131 | 1.1.4.2.4.2 | Floor Tiles | milestone | 350d | 2024-01-02 | 2025-02-28 | 2024-01-02 | 2025-02-28 | 350d | 0d | 0% |
| 132 | 1.1.4.2.4.3 | Wall Tiles | milestone | 350d | 2024-01-02 | 2025-02-28 | 2024-01-02 | 2025-02-28 | 350d | 0d | 0% |
| 133 | 1.1.4.2.5 | **Wall** |  | 380d | 2024-01-02 | 2025-04-07 |  |  |  | 0d | 0% |
| 134 | 1.1.4.2.5.1 | Common Clay Brick | milestone | 360d | 2024-01-02 | 2025-03-12 | 2024-01-02 | 2025-03-12 | 360d | 0d | 0% |
| 135 | 1.1.4.2.5.2 | Lightweight Concrete Panel | milestone | 360d | 2024-01-02 | 2025-03-12 | 2024-01-02 | 2025-03-12 | 360d | 0d | 0% |
| 136 | 1.1.4.2.5.3 | Plaster (Cement) | milestone | 380d | 2024-01-02 | 2025-04-07 | 2024-01-02 | 2025-04-07 | 380d | 0d | 0% |
| 137 | 1.1.4.2.5.4 | Skim Coat | milestone | 380d | 2024-01-02 | 2025-04-07 | 2024-01-02 | 2025-04-07 | 380d | 0d | 0% |
| 138 | 1.1.4.2.6 | Painting | milestone | 343d | 2024-01-02 | 2025-02-20 | 2024-01-02 | 2025-02-20 | 343d | 0d | 0% |
| 139 | 1.1.4.2.7 | **Ceiling** |  | 300d | 2024-01-02 | 2024-12-28 |  |  |  | 0d | 0% |
| 140 | 1.1.4.2.7.1 | Mineral Fibre Board | milestone | 300d | 2024-01-02 | 2024-12-28 | 2024-01-02 | 2024-12-28 | 300d | 0d | 0% |
| 141 | 1.1.4.2.7.2 | Calcium Silicate Board | milestone | 300d | 2024-01-02 | 2024-12-28 | 2024-01-02 | 2024-12-28 | 300d | 0d | 0% |
| 142 | 1.1.4.2.8 | **Mild Steel Works** |  | 340d | 2024-01-02 | 2025-02-17 |  |  |  | 0d | 0% |
| 143 | 1.1.4.2.8.1 | Stainless Steel Railing | milestone | 340d | 2024-01-02 | 2025-02-17 | 2024-01-02 | 2025-02-17 | 340d | 0d | 0% |
| 144 | 1.1.4.2.8.2 | Column Guard |  | 30d | 2024-01-02 | 2024-02-05 | 2024-01-02 | 2024-02-05 | 30d | 0d | 0% |
| 145 | 1.1.4.3 | **M&E Procurement** |  | 360d | 2024-01-02 | 2025-03-12 |  |  |  | 0d | 0% |
| 146 | 1.1.4.3.1 | **Eletrical & ELV Services** |  | 200d | 2024-01-02 | 2024-08-28 |  |  |  | 0d | 0% |
| 147 | 1.1.4.3.1.1 | Cable | milestone | 200d | 2024-01-02 | 2024-08-28 | 2024-01-02 | 2024-08-28 | 200d | 0d | 0% |
| 148 | 1.1.4.3.1.2 | HT Cable | milestone | 200d | 2024-01-02 | 2024-08-28 | 2024-01-02 | 2024-08-28 | 200d | 0d | 0% |
| 149 | 1.1.4.3.1.3 | LV Busduct | milestone | 200d | 2024-01-02 | 2024-08-28 | 2024-01-02 | 2024-08-28 | 200d | 0d | 0% |
| 150 | 1.1.4.3.1.4 | ELV System | milestone | 200d | 2024-01-02 | 2024-08-28 | 2024-01-02 | 2024-08-28 | 200d | 0d | 0% |
| 151 | 1.1.4.3.1.5 | HT Equipment | milestone | 100d | 2024-01-02 | 2024-04-29 | 2024-01-02 | 2024-04-29 | 100d | 0d | 0% |
| 152 | 1.1.4.3.1.6 | Electrical Switchboard | milestone | 100d | 2024-01-02 | 2024-04-29 | 2024-01-02 | 2024-04-29 | 100d | 0d | 0% |
| 153 | 1.1.4.3.1.7 | Light Fitting | milestone | 100d | 2024-01-02 | 2024-04-29 | 2024-01-02 | 2024-04-29 | 100d | 0d | 0% |

| ID | WBS | Task | Type | Duration | Start | Finish | Baseline start | Baseline finish | Baseline duration | Total slack | %Planned |
| --- | --- | --- | --- | --- | --- | --- | --- | --- | --- | --- | --- |
| 154 | 1.1.4.3.2 | **Plumbing and Sanitary Services** |  | 340d | 2024-01-02 | 2025-02-17 |  |  |  | 0d | 0% |
| 155 | 1.1.4.3.2.1 | Piping & Fitting | milestone | 340d | 2024-01-02 | 2025-02-17 | 2024-01-02 | 2025-02-17 | 340d | 0d | 0% |
| 156 | 1.1.4.3.2.2 | Sanitary Wares & Fitting | milestone | 40d | 2024-01-02 | 2024-02-16 | 2024-01-02 | 2024-02-16 | 40d | 0d | 0% |
| 157 | 1.1.4.3.2.3 | Pump & Pump Panel | milestone | 40d | 2024-01-02 | 2024-02-16 | 2024-01-02 | 2024-02-16 | 40d | 0d | 0% |
| 158 | 1.1.4.3.3 | **ACMV Services** |  | 120d | 2024-01-02 | 2024-05-24 |  |  |  | 0d | 0% |
| 159 | 1.1.4.3.3.1 | Wiring, Drain Pipe, Copper Pipe | milestone | 110d | 2024-01-02 | 2024-05-11 | 2024-01-02 | 2024-05-11 | 110d | 0d | 0% |
| 160 | 1.1.4.3.3.2 | Exhaust Duct | milestone | 120d | 2024-01-02 | 2024-05-24 | 2024-01-02 | 2024-05-24 | 120d | 0d | 0% |
| 161 | 1.1.4.3.3.3 | Fan, Indoor & Outdoor Unit | milestone | 100d | 2024-01-02 | 2024-04-29 | 2024-01-02 | 2024-04-29 | 100d | 0d | 0% |
| 162 | 1.1.4.3.3.4 | Grilles / Lourvres | milestone | 100d | 2024-01-02 | 2024-04-29 | 2024-01-02 | 2024-04-29 | 100d | 0d | 0% |
| 163 | 1.1.4.3.4 | **Fire Protection Services** |  | 360d | 2024-01-02 | 2025-03-12 |  |  |  | 0d | 0% |
| 164 | 1.1.4.3.4.1 | Pipe & Fittings | milestone | 360d | 2024-01-02 | 2025-03-12 | 2024-01-02 | 2025-03-12 | 360d | 0d | 0% |
| 165 | 1.1.4.3.4.2 | Sprinkler Tank | milestone | 30d | 2024-01-02 | 2024-02-05 | 2024-01-02 | 2024-02-05 | 30d | 0d | 0% |
| 166 | 1.1.4.3.4.3 | Hose Reel Tank | milestone | 30d | 2024-01-02 | 2024-02-05 | 2024-01-02 | 2024-02-05 | 30d | 0d | 0% |
| 167 | 1.1.4.3.4.4 | Fire Alarm Panel | milestone | 120d | 2024-01-02 | 2024-05-24 | 2024-01-02 | 2024-05-24 | 120d | 0d | 0% |
| 168 | 1.1.4.3.4.5 | Pump & Panel | milestone | 120d | 2024-01-02 | 2024-05-24 | 2024-01-02 | 2024-05-24 | 120d | 0d | 0% |
| 169 | 1.1.4.3.5 | **Lift & Goods Hoist Services** |  | 180d | 2024-01-02 | 2024-08-05 |  |  |  | 0d | 0% |
| 170 | 1.1.4.3.5.1 | Lift Car & Accessories | milestone | 180d | 2024-01-02 | 2024-08-05 | 2024-01-02 | 2024-08-05 | 180d | 0d | 0% |
| 171 | 1.1.4.4 | **Infrastructure Procurement** |  | 90d | 2024-01-02 | 2024-04-17 |  |  |  | 0d | 0% |
| 172 | 1.1.4.4.1 | **Drainage** |  | 90d | 2024-01-02 | 2024-04-17 |  |  |  | 0d | 0% |
| 173 | 1.1.4.4.1.1 | SGW Drain | milestone | 90d | 2024-01-02 | 2024-04-17 | 2024-01-02 | 2024-04-17 | 90d | 0d | 0% |
| 174 | 1.1.4.4.1.2 | MS Grating | milestone | 90d | 2024-01-02 | 2024-04-17 | 2024-01-02 | 2024-04-17 | 90d | 0d | 0% |
| 175 | 1.1.4.4.2 | **Sewerage** |  | 90d | 2024-01-02 | 2024-04-17 |  |  |  | 0d | 0% |
| 176 | 1.1.4.4.2.1 | 225mm dia VCP Pipe | milestone | 90d | 2024-01-02 | 2024-04-17 | 2024-01-02 | 2024-04-17 | 90d | 0d | 0% |
| 177 | 1.1.4.4.2.2 | Precast Manhole | milestone | 90d | 2024-01-02 | 2024-04-17 | 2024-01-02 | 2024-04-17 | 90d | 0d | 0% |

| ID | WBS | Task | Type | Duration | Start | Finish | Predecessors | Baseline start | Baseline finish | Baseline duration | Total slack | Constraint | Cost | %Planned |
| --- | --- | --- | --- | --- | --- | --- | --- | --- | --- | --- | --- | --- | --- | --- |
| 178 | 1.1.4.4.3 | **Fencing and Gate** |  | 60d | 2024-01-02 | 2024-03-11 |  |  |  |  | 0d |  |  | 0% |
| 179 | 1.1.4.4.3.1 | Entrance Gate | milestone | 60d | 2024-01-02 | 2024-03-11 |  | 2024-01-02 | 2024-03-11 | 60d | 0d |  |  | 0% |
| 180 | 1.2 | **Building Work** |  | 747d | 2023-10-12 | 2026-03-25 |  |  |  |  | 0d |  | 110 | 0% |
| 181 | 1.2.1 | **Preliminaries Works** |  | 680d | 2024-01-02 | 2026-03-25 |  |  |  |  | 0d |  | 110 | 0% |
| 182 | 1.2.1.1 | **Preliminaries Works** |  | 680d | 2024-01-02 | 2026-03-25 |  |  |  |  | 0d |  |  | 0% |
| 183 | 1.2.1.1.1 | Initial Preliminaries |  | 30d | 2024-01-02 | 2024-02-05 | 213FS-1d |  |  |  | 0d |  |  | 0% |
| 184 | 1.2.1.1.2 | **Recurring Preliminaries** |  | 660d | 2024-01-25 | 2026-03-25 |  |  |  |  | 0d |  |  | 0% |
| 185 | 1.2.1.1.2.1 | Recurring Preliminaries 1 | manual | 1d | 2024-01-25 | 2024-01-25 |  |  |  |  |  | start no earlier than 2024-01-25 |  |  |
| 186 | 1.2.1.1.2.2 | Recurring Preliminaries 2 | manual | 1d | 2024-02-25 | 2024-02-25 |  |  |  |  |  | start no earlier than 2024-02-25 |  |  |
| 187 | 1.2.1.1.2.3 | Recurring Preliminaries 3 | manual | 1d | 2024-03-25 | 2024-03-25 |  |  |  |  |  | start no earlier than 2024-03-25 |  |  |
| 188 | 1.2.1.1.2.4 | Recurring Preliminaries 4 | manual | 1d | 2024-04-25 | 2024-04-25 |  |  |  |  |  | start no earlier than 2024-04-25 |  |  |
| 189 | 1.2.1.1.2.5 | Recurring Preliminaries 5 | manual | 1d | 2024-05-25 | 2024-05-25 |  |  |  |  |  | start no earlier than 2024-05-25 |  |  |
| 190 | 1.2.1.1.2.6 | Recurring Preliminaries 6 | manual | 1d | 2024-06-25 | 2024-06-25 |  |  |  |  |  | start no earlier than 2024-06-25 |  |  |
| 191 | 1.2.1.1.2.7 | Recurring Preliminaries 7 | manual | 1d | 2024-07-25 | 2024-07-25 |  |  |  |  |  | start no earlier than 2024-07-25 |  |  |
| 192 | 1.2.1.1.2.8 | Recurring Preliminaries 8 | manual | 1d | 2024-08-25 | 2024-08-25 |  |  |  |  |  | start no earlier than 2024-08-25 |  |  |
| 193 | 1.2.1.1.2.9 | Recurring Preliminaries 9 | manual | 1d | 2024-09-25 | 2024-09-25 |  |  |  |  |  | start no earlier than 2024-09-25 |  |  |
| 194 | 1.2.1.1.2.10 | Recurring Preliminaries 10 | manual | 1d | 2024-10-25 | 2024-10-25 |  |  |  |  |  | start no earlier than 2024-10-25 |  |  |
| 195 | 1.2.1.1.2.11 | Recurring Preliminaries 11 | manual | 1d | 2024-11-25 | 2024-11-25 |  |  |  |  |  | start no earlier than 2024-11-25 |  |  |
| 196 | 1.2.1.1.2.12 | Recurring Preliminaries 12 | manual | 1d | 2024-12-25 | 2024-12-25 |  |  |  |  |  | start no earlier than 2024-12-25 |  |  |
| 197 | 1.2.1.1.2.13 | Recurring Preliminaries 13 | manual | 1d | 2025-01-25 | 2025-01-25 |  |  |  |  |  | start no earlier than 2025-01-25 |  |  |
| 198 | 1.2.1.1.2.14 | Recurring Preliminaries 14 | manual | 1d | 2025-02-25 | 2025-02-25 |  |  |  |  |  | start no earlier than 2025-02-25 |  |  |
| 199 | 1.2.1.1.2.15 | Recurring Preliminaries 15 | manual | 1d | 2025-03-25 | 2025-03-25 |  |  |  |  |  | start no earlier than 2025-03-25 |  |  |
| 200 | 1.2.1.1.2.16 | Recurring Preliminaries 16 | manual | 1d | 2025-04-25 | 2025-04-25 |  |  |  |  |  | start no earlier than 2025-04-25 |  |  |
| 201 | 1.2.1.1.2.17 | Recurring Preliminaries 17 | manual | 1d | 2025-05-25 | 2025-05-25 |  |  |  |  |  | start no earlier than 2025-05-25 |  |  |
| 202 | 1.2.1.1.2.18 | Recurring Preliminaries 18 | manual | 1d | 2025-06-25 | 2025-06-25 |  |  |  |  |  | start no earlier than 2025-06-25 |  |  |
| 203 | 1.2.1.1.2.19 | Recurring Preliminaries 19 | manual | 1d | 2025-07-25 | 2025-07-25 |  |  |  |  |  | start no earlier than 2025-07-25 |  |  |
| 204 | 1.2.1.1.2.20 | Recurring Preliminaries 20 | manual | 1d | 2025-08-25 | 2025-08-25 |  |  |  |  |  | start no earlier than 2025-08-25 |  |  |
| 205 | 1.2.1.1.2.21 | Recurring Preliminaries 21 | manual | 1d | 2025-09-25 | 2025-09-25 |  |  |  |  |  | start no earlier than 2025-09-25 |  |  |
| 206 | 1.2.1.1.2.22 | Recurring Preliminaries 22 | manual | 1d | 2025-10-25 | 2025-10-25 |  |  |  |  |  | start no earlier than 2025-10-25 |  |  |
| 207 | 1.2.1.1.2.23 | Recurring Preliminaries 23 | manual | 1d | 2025-11-25 | 2025-11-25 |  |  |  |  |  | start no earlier than 2025-11-25 |  |  |
| 208 | 1.2.1.1.2.24 | Recurring Preliminaries 24 | manual | 1d | 2025-12-25 | 2025-12-25 |  |  |  |  |  | start no earlier than 2025-12-25 |  |  |
| 209 | 1.2.1.1.2.25 | Recurring Preliminaries 25 | manual | 1d | 2026-01-25 | 2026-01-25 |  |  |  |  |  | start no earlier than 2026-01-25 |  |  |
| 210 | 1.2.1.1.2.26 | Recurring Preliminaries 26 | manual | 1d | 2026-02-25 | 2026-02-25 |  |  |  |  |  | start no earlier than 2026-02-25 |  |  |
| 211 | 1.2.1.1.2.27 | Recurring Preliminaries 27 | manual | 1d | 2026-03-25 | 2026-03-25 |  |  |  |  |  | start no earlier than 2026-03-25 |  |  |
| 212 | 1.2.1.1.3 | Final Preliminaries |  | 30d | 2024-01-02 | 2024-02-05 |  |  |  |  | 0d |  |  | 0% |
| 213 | 1.2.1.2 | Site Commencement |  | 1d | 2024-01-02 | 2024-01-02 |  |  |  |  | 0d | must start on 2024-01-02 |  | 0% |
| 214 | 1.2.1.3 | Site Survey |  | 30d | 2024-01-03 | 2024-02-06 | 213 |  |  |  | 0d |  | 10 | 0% |
| 215 | 1.2.1.4 | Site Preparation Works |  | 14d | 2024-02-07 | 2024-02-22 | 214 |  |  |  | 0d |  | 100 | 0% |
| 216 | 1.2.1.5 | Site Office & Accomodation |  | 30d | 2024-02-23 | 2024-03-28 | 215 |  |  |  | 0d |  |  | 0% |

| ID | WBS | Task | Duration | Start | Finish | Predecessors | Baseline start | Baseline finish | Baseline duration | Total slack | %Planned |
| --- | --- | --- | --- | --- | --- | --- | --- | --- | --- | --- | --- |
| 217 | 1.2.1.6 | **Tower Crane** | 30d | 2024-01-02 | 2024-02-05 |  |  |  |  | 0d | 0% |
| 218 | 1.2.1.6.1 | Tower Crane (1) Foundation, Installation, JKKP Inspection | 30d | 2024-01-02 | 2024-02-05 |  | 2024-01-02 | 2024-02-05 | 30d | 0d | 0% |
| 219 | 1.2.1.6.2 | Tower Crane (1) Dismantle | 30d | 2024-01-02 | 2024-02-05 |  | 2024-01-02 | 2024-02-05 | 30d | 0d | 0% |
| 220 | 1.2.1.7 | **Passenger Hoist** | 14d | 2024-01-02 | 2024-01-17 |  |  |  |  | 0d | 0% |
| 221 | 1.2.1.7.1 | Passenger Hoist - Foundation | 14d | 2024-01-02 | 2024-01-17 |  | 2024-01-02 | 2024-01-17 | 14d | 0d | 0% |
| 222 | 1.2.1.7.2 | Passenger Hoist Install | 14d | 2024-01-02 | 2024-01-17 |  | 2024-01-02 | 2024-01-17 | 14d | 0d | 0% |
| 223 | 1.2.1.7.3 | Passenger Hoist Dismantle | 14d | 2024-01-02 | 2024-01-17 |  | 2024-01-02 | 2024-01-17 | 14d | 0d | 0% |
| 224 | 1.2.2 | **Sub-Structure** | 125d | 2024-01-20 | 2024-06-20 |  |  |  |  | 0d | 0% |
| 225 | 1.2.2.1 | Soil Back Filing | 80d | 2024-01-26 | 2024-04-30 | 214FS-10d |  |  |  | 0d | 0% |
| 226 | 1.2.2.2 | **Piling Work** | 125d | 2024-01-20 | 2024-06-20 |  |  |  |  | 0d | 0% |
| 227 | 1.2.2.2.1 | MLT Test | 45d | 2024-01-20 | 2024-03-12 | 214FS-15d |  |  |  | 0d | 0% |
| 228 | 1.2.2.2.2 | **Piling** | 80d | 2024-03-13 | 2024-06-20 |  |  |  |  | 0d | 0% |
| 229 | 1.2.2.2.2.1 | Zone 1 | 20d | 2024-03-13 | 2024-04-04 | 227 | 2024-03-13 | 2024-04-04 | 20d | 0d | 0% |
| 230 | 1.2.2.2.2.2 | Zone 2 | 20d | 2024-03-30 | 2024-04-24 | 229FS-5d | 2024-03-30 | 2024-04-24 | 20d | 0d | 0% |
| 231 | 1.2.2.2.2.3 | Zone 3 | 20d | 2024-04-19 | 2024-05-13 | 230FS-5d | 2024-04-19 | 2024-05-13 | 20d | 0d | 0% |
| 232 | 1.2.2.2.2.4 | Zone 4 | 20d | 2024-05-08 | 2024-05-31 | 231FS-5d | 2024-05-08 | 2024-05-31 | 20d | 0d | 0% |
| 233 | 1.2.2.2.2.5 | PDA Test | 60d | 2024-04-05 | 2024-06-20 | 229 | 2024-04-05 | 2024-06-20 | 60d | 0d | 0% |
| 234 | 1.2.2.3 | **Pile Cap & Stump** | 45d | 2024-04-05 | 2024-05-31 |  |  |  |  | 0d | 0% |
| 235 | 1.2.2.3.1 | **Zone 1** | 15d | 2024-04-05 | 2024-04-24 |  |  |  |  | 0d | 0% |
| 236 | 1.2.2.3.1.1 | Formwork | 10d | 2024-04-05 | 2024-04-18 | 229 | 2024-04-05 | 2024-04-18 | 10d | 0d | 0% |
| 237 | 1.2.2.3.1.2 | Reinforcement | 10d | 2024-04-13 | 2024-04-24 | 236FS-5d | 2024-04-13 | 2024-04-24 | 10d | 0d | 0% |
| 238 | 1.2.2.3.1.3 | Concrete | 4d | 2024-04-20 | 2024-04-24 | 237FS-4d | 2024-04-20 | 2024-04-24 | 4d | 0d | 0% |
| 239 | 1.2.2.3.2 | **Zone 2** | 15d | 2024-04-19 | 2024-05-07 |  |  |  |  | 0d | 0% |
| 240 | 1.2.2.3.2.1 | Formwork | 10d | 2024-04-19 | 2024-04-30 | 236 | 2024-04-19 | 2024-04-30 | 10d | 0d | 0% |
| 241 | 1.2.2.3.2.2 | Reinforcement | 10d | 2024-04-25 | 2024-05-07 | 240FS-5d | 2024-04-25 | 2024-05-07 | 10d | 0d | 0% |
| 242 | 1.2.2.3.2.3 | Concrete | 4d | 2024-05-03 | 2024-05-07 | 241FS-4d | 2024-05-03 | 2024-05-07 | 4d | 0d | 0% |

| ID | WBS | Task | Duration | Start | Finish | Predecessors | Baseline start | Baseline finish | Baseline duration | Total slack | %Planned |
| --- | --- | --- | --- | --- | --- | --- | --- | --- | --- | --- | --- |
| 243 | 1.2.2.3.3 | **Zone 3** | 15d | 2024-05-02 | 2024-05-18 |  |  |  |  | 0d | 0% |
| 244 | 1.2.2.3.3.1 | Formwork | 10d | 2024-05-02 | 2024-05-13 | 240 | 2024-05-02 | 2024-05-13 | 10d | 0d | 0% |
| 245 | 1.2.2.3.3.2 | Reinforcement | 10d | 2024-05-08 | 2024-05-18 | 244FS-5d | 2024-05-08 | 2024-05-18 | 10d | 0d | 0% |
| 246 | 1.2.2.3.3.3 | Concrete | 4d | 2024-05-15 | 2024-05-18 | 245FS-4d | 2024-05-15 | 2024-05-18 | 4d | 0d | 0% |
| 247 | 1.2.2.3.4 | **Zone 4** | 15d | 2024-05-14 | 2024-05-31 |  |  |  |  | 0d | 0% |
| 248 | 1.2.2.3.4.1 | Formwork | 10d | 2024-05-14 | 2024-05-25 | 244 | 2024-05-14 | 2024-05-25 | 10d | 0d | 0% |
| 249 | 1.2.2.3.4.2 | Reinforcement | 10d | 2024-05-20 | 2024-05-31 | 248FS-5d | 2024-05-20 | 2024-05-31 | 10d | 0d | 0% |
| 250 | 1.2.2.3.4.3 | Concrete | 4d | 2024-05-28 | 2024-05-31 | 249FS-4d | 2024-05-28 | 2024-05-31 | 4d | 0d | 0% |
| 251 | 1.2.3 | **Super-Structure** | 329d | 2023-10-12 | 2024-11-12 |  |  |  |  | 0d | 0% |
| 252 | 1.2.3.1 | **Podium** | 241d | 2024-01-15 | 2024-10-30 |  |  |  |  | 0d | 0% |
| 253 | 1.2.3.1.1 | **Ground Floor** | 97d | 2024-05-08 | 2024-09-02 |  |  |  |  | 0d | 0% |
| 254 | 1.2.3.1.1.1 | **Zone A** | 87d | 2024-05-08 | 2024-08-20 |  |  |  |  | 0d | 0% |
| 255 | 1.2.3.1.1.1.1 | **Beam & Slab (GF)** | 16d | 2024-05-08 | 2024-05-27 |  |  |  |  | 0d | 0% |
| 256 | 1.2.3.1.1.1.1.1 | Formwork | 10d | 2024-05-08 | 2024-05-18 | 242 | 2024-05-08 | 2024-05-18 | 10d | 0d | 0% |
| 257 | 1.2.3.1.1.1.1.2 | Reinforcement | 10d | 2024-05-14 | 2024-05-25 | 256FS-5d | 2024-05-14 | 2024-05-25 | 10d | 0d | 0% |
| 258 | 1.2.3.1.1.1.1.3 | Concrete | 3d | 2024-05-24 | 2024-05-27 | 257FS-2d | 2024-05-24 | 2024-05-27 | 3d | 0d | 0% |
| 259 | 1.2.3.1.1.1.2 | Post Tension Stressing | 2d | 2024-06-06 | 2024-06-07 | 258FS+7d |  |  |  | 0d | 0% |
| 260 | 1.2.3.1.1.1.3 | **Column & Wall (GF)** | 18d | 2024-05-28 | 2024-06-19 |  |  |  |  | 0d | 0% |
| 261 | 1.2.3.1.1.1.3.1 | Reinforcement | 14d | 2024-05-28 | 2024-06-13 | 258 | 2024-05-28 | 2024-06-13 | 14d | 0d | 0% |
| 262 | 1.2.3.1.1.1.3.2 | Formwork | 10d | 2024-06-06 | 2024-06-18 | 261FS-7d | 2024-06-06 | 2024-06-18 | 10d | 0d | 0% |
| 263 | 1.2.3.1.1.1.3.3 | Concrete | 3d | 2024-06-15 | 2024-06-19 | 262FS-2d | 2024-06-15 | 2024-06-19 | 3d | 0d | 0% |
| 264 | 1.2.3.1.1.1.4 | Dismantle Propping | 3d | 2024-08-17 | 2024-08-20 | 304 |  |  |  | 0d | 0% |
| 265 | 1.2.3.1.1.2 | **Zone B** | 87d | 2024-05-20 | 2024-09-02 |  |  |  |  | 0d | 0% |
| 266 | 1.2.3.1.1.2.1 | **Beam & Slab (GF)** | 16d | 2024-05-20 | 2024-06-08 |  |  |  |  | 0d | 0% |
| 267 | 1.2.3.1.1.2.1.1 | Formwork | 10d | 2024-05-20 | 2024-05-31 | 256 |  |  |  | 0d | 0% |
| 268 | 1.2.3.1.1.2.1.2 | Reinforcement | 10d | 2024-05-27 | 2024-06-07 | 267FS-5d |  |  |  | 0d | 0% |
| 269 | 1.2.3.1.1.2.1.3 | Concrete | 3d | 2024-06-06 | 2024-06-08 | 268FS-2d |  |  |  | 0d | 0% |
| 270 | 1.2.3.1.1.2.2 | Post Tension Stressing | 2d | 2024-06-19 | 2024-06-20 | 269FS+7d |  |  |  | 0d | 0% |

| ID | WBS | Task | Duration | Start | Finish | Predecessors | Baseline start | Baseline finish | Baseline duration | Total slack | %Planned |
| --- | --- | --- | --- | --- | --- | --- | --- | --- | --- | --- | --- |
| 271 | 1.2.3.1.1.2.3 | **Column & Wall (GF)** | 18d | 2024-06-10 | 2024-07-01 |  |  |  |  | 0d | 0% |
| 272 | 1.2.3.1.1.2.3.1 | Reinforcement | 14d | 2024-06-10 | 2024-06-26 | 269 |  |  |  | 0d | 0% |
| 273 | 1.2.3.1.1.2.3.2 | Formwork | 10d | 2024-06-19 | 2024-06-29 | 272FS-7d |  |  |  | 0d | 0% |
| 274 | 1.2.3.1.1.2.3.3 | Concrete | 3d | 2024-06-28 | 2024-07-01 | 273FS-2d |  |  |  | 0d | 0% |
| 275 | 1.2.3.1.1.2.4 | Dismantle Propping | 3d | 2024-08-29 | 2024-09-02 | 315 |  |  |  | 0d | 0% |
| 276 | 1.2.3.1.2 | **Level 1** | 97d | 2024-06-20 | 2024-10-12 |  |  |  |  | 0d | 0% |
| 277 | 1.2.3.1.2.1 | **Zone A** | 87d | 2024-06-20 | 2024-10-01 |  |  |  |  | 0d | 0% |
| 278 | 1.2.3.1.2.1.1 | **Beam & Slab (L1)** | 87d | 2024-06-20 | 2024-10-01 |  |  |  |  | 0d | 0% |
| 279 | 1.2.3.1.2.1.1.1 | Formwork | 10d | 2024-06-20 | 2024-07-01 | 263 | 2024-06-20 | 2024-07-01 | 10d | 0d | 0% |
| 280 | 1.2.3.1.2.1.1.2 | Reinforcement | 10d | 2024-06-26 | 2024-07-06 | 279FS-5d | 2024-06-26 | 2024-07-06 | 10d | 0d | 0% |
| 281 | 1.2.3.1.2.1.1.3 | Concrete | 3d | 2024-07-05 | 2024-07-08 | 280FS-2d | 2024-07-05 | 2024-07-08 | 3d | 0d | 0% |
| 282 | 1.2.3.1.2.1.1.4 | Post Tension Stressing | 2d | 2024-07-17 | 2024-07-18 | 281FS+7d | 2024-07-17 | 2024-07-18 | 2d | 0d | 0% |
| 283 | 1.2.3.1.2.1.1.5 | **Column & Wall (L1)** | 18d | 2024-07-09 | 2024-07-29 |  |  |  |  | 0d | 0% |
| 284 | 1.2.3.1.2.1.1.5.1 | Reinforcement | 14d | 2024-07-09 | 2024-07-24 | 281 | 2024-07-09 | 2024-07-24 | 14d | 0d | 0% |
| 285 | 1.2.3.1.2.1.1.5.2 | Formwork | 10d | 2024-07-17 | 2024-07-27 | 284FS-7d | 2024-07-17 | 2024-07-27 | 10d | 0d | 0% |
| 286 | 1.2.3.1.2.1.1.5.3 | Concrete | 3d | 2024-07-26 | 2024-07-29 | 285FS-2d | 2024-07-26 | 2024-07-29 | 3d | 0d | 0% |
| 287 | 1.2.3.1.2.1.1.6 | Dismantle Propping | 3d | 2024-09-28 | 2024-10-01 | 327 | 2024-09-28 | 2024-10-01 | 3d | 0d | 0% |
| 288 | 1.2.3.1.2.2 | **Zone B** | 87d | 2024-07-02 | 2024-10-12 |  |  |  |  | 0d | 0% |
| 289 | 1.2.3.1.2.2.1 | **Beam & Slab (L1)** | 16d | 2024-07-02 | 2024-07-19 |  |  |  |  | 0d | 0% |
| 290 | 1.2.3.1.2.2.1.1 | Formwork | 10d | 2024-07-02 | 2024-07-12 | 279 |  |  |  | 0d | 0% |
| 291 | 1.2.3.1.2.2.1.2 | Reinforcement | 10d | 2024-07-08 | 2024-07-18 | 290FS-5d |  |  |  | 0d | 0% |
| 292 | 1.2.3.1.2.2.1.3 | Concrete | 3d | 2024-07-17 | 2024-07-19 | 291FS-2d |  |  |  | 0d | 0% |
| 293 | 1.2.3.1.2.2.2 | Post Tension Stressing | 2d | 2024-07-29 | 2024-07-30 | 292FS+7d |  |  |  | 0d | 0% |
| 294 | 1.2.3.1.2.2.3 | **Column & Wall (L1)** | 18d | 2024-07-20 | 2024-08-09 |  |  |  |  | 0d | 0% |
| 295 | 1.2.3.1.2.2.3.1 | Reinforcement | 14d | 2024-07-20 | 2024-08-05 | 292 |  |  |  | 0d | 0% |
| 296 | 1.2.3.1.2.2.3.2 | Formwork | 10d | 2024-07-29 | 2024-08-08 | 295FS-7d |  |  |  | 0d | 0% |
| 297 | 1.2.3.1.2.2.3.3 | Concrete | 3d | 2024-08-07 | 2024-08-09 | 296FS-2d |  |  |  | 0d | 0% |
| 298 | 1.2.3.1.2.2.4 | Dismantle Propping | 3d | 2024-10-10 | 2024-10-12 | 338 |  |  |  | 0d | 0% |

| ID | WBS | Task | Duration | Start | Finish | Predecessors | Baseline start | Baseline finish | Baseline duration | Total slack | %Planned |
| --- | --- | --- | --- | --- | --- | --- | --- | --- | --- | --- | --- |
| 299 | 1.2.3.1.3 | **Level 2** | 207d | 2024-01-15 | 2024-09-20 |  |  |  |  | 0d | 0% |
| 300 | 1.2.3.1.3.1 | **Zone A** | 197d | 2024-01-15 | 2024-09-07 |  |  |  |  | 0d | 0% |
| 301 | 1.2.3.1.3.1.1 | **Beam & Slab (L2)** | 16d | 2024-07-30 | 2024-08-16 |  |  |  |  | 0d | 0% |
| 302 | 1.2.3.1.3.1.1.1 | Formwork | 10d | 2024-07-30 | 2024-08-09 | 286 | 2024-07-30 | 2024-08-09 | 10d | 0d | 0% |
| 303 | 1.2.3.1.3.1.1.2 | Reinforcement | 10d | 2024-08-05 | 2024-08-15 | 302FS-5d | 2024-08-05 | 2024-08-15 | 10d | 0d | 0% |
| 304 | 1.2.3.1.3.1.1.3 | Concrete | 3d | 2024-08-14 | 2024-08-16 | 303FS-2d | 2024-08-14 | 2024-08-16 | 3d | 0d | 0% |
| 305 | 1.2.3.1.3.1.2 | Post Tension Stressing | 2d | 2024-08-26 | 2024-08-27 | 304FS+7d | 2024-08-26 | 2024-08-27 | 2d | 0d | 0% |
| 306 | 1.2.3.1.3.1.3 | **Column & Wall (L2)** | 18d | 2024-08-17 | 2024-09-07 |  |  |  |  | 0d | 0% |
| 307 | 1.2.3.1.3.1.3.1 | Reinforcement | 14d | 2024-08-17 | 2024-09-03 | 304 | 2024-08-17 | 2024-09-03 | 14d | 0d | 0% |
| 308 | 1.2.3.1.3.1.3.2 | Formwork | 10d | 2024-08-26 | 2024-09-06 | 307FS-7d | 2024-08-26 | 2024-09-06 | 10d | 0d | 0% |
| 309 | 1.2.3.1.3.1.3.3 | Concrete | 3d | 2024-09-05 | 2024-09-07 | 308FS-2d | 2024-09-05 | 2024-09-07 | 3d | 0d | 0% |
| 310 | 1.2.3.1.3.1.4 | Dismantle Propping | 3d | 2024-01-15 | 2024-01-17 | 354 | 2024-11-08 | 2024-11-11 | 3d | 0d | 0% |
| 311 | 1.2.3.1.3.2 | **Zone B** | 207d | 2024-01-15 | 2024-09-20 |  |  |  |  | 0d | 0% |
| 312 | 1.2.3.1.3.2.1 | **Beam & Slab (L2)** | 16d | 2024-08-10 | 2024-08-28 |  |  |  |  | 0d | 0% |
| 313 | 1.2.3.1.3.2.1.1 | Formwork | 10d | 2024-08-10 | 2024-08-21 | 302 |  |  |  | 0d | 0% |
| 314 | 1.2.3.1.3.2.1.2 | Reinforcement | 10d | 2024-08-16 | 2024-08-27 | 313FS-5d |  |  |  | 0d | 0% |
| 315 | 1.2.3.1.3.2.1.3 | Concrete | 3d | 2024-08-26 | 2024-08-28 | 314FS-2d |  |  |  | 0d | 0% |
| 316 | 1.2.3.1.3.2.2 | Post Tension Stressing | 2d | 2024-09-07 | 2024-09-09 | 315FS+7d |  |  |  | 0d | 0% |
| 317 | 1.2.3.1.3.2.3 | **Column & Wall (L2)** | 18d | 2024-08-29 | 2024-09-20 |  |  |  |  | 0d | 0% |
| 318 | 1.2.3.1.3.2.3.1 | Reinforcement | 14d | 2024-08-29 | 2024-09-14 | 315 |  |  |  | 0d | 0% |
| 319 | 1.2.3.1.3.2.3.2 | Formwork | 10d | 2024-09-07 | 2024-09-19 | 318FS-7d |  |  |  | 0d | 0% |
| 320 | 1.2.3.1.3.2.3.3 | Concrete | 3d | 2024-09-18 | 2024-09-20 | 319FS-2d |  |  |  | 0d | 0% |
| 321 | 1.2.3.1.3.2.4 | Dismantle Propping | 3d | 2024-01-15 | 2024-01-17 | 360 |  |  |  | 0d | 0% |
| 322 | 1.2.3.1.4 | **Level 3** | 241d | 2024-01-15 | 2024-10-30 |  |  |  |  | 0d | 0% |
| 323 | 1.2.3.1.4.1 | **Zone A** | 231d | 2024-01-15 | 2024-10-18 |  |  |  |  | 0d | 0% |
| 324 | 1.2.3.1.4.1.1 | **Beam & Slab (L3)** | 16d | 2024-09-09 | 2024-09-27 |  |  |  |  | 0d | 0% |
| 325 | 1.2.3.1.4.1.1.1 | Formwork | 10d | 2024-09-09 | 2024-09-20 | 309 | 2024-09-09 | 2024-09-20 | 10d | 0d | 0% |
| 326 | 1.2.3.1.4.1.1.2 | Reinforcement | 10d | 2024-09-14 | 2024-09-26 | 325FS-5d | 2024-09-14 | 2024-09-26 | 10d | 0d | 0% |
| 327 | 1.2.3.1.4.1.1.3 | Concrete | 3d | 2024-09-25 | 2024-09-27 | 326FS-2d | 2024-09-25 | 2024-09-27 | 3d | 0d | 0% |
| 328 | 1.2.3.1.4.1.2 | Post Tension Stressing | 2d | 2024-09-28 | 2024-09-30 | 327 | 2024-09-28 | 2024-09-30 | 2d | 0d | 0% |

| ID | WBS | Task | Duration | Start | Finish | Predecessors | Baseline start | Baseline finish | Baseline duration | Total slack | %Planned |
| --- | --- | --- | --- | --- | --- | --- | --- | --- | --- | --- | --- |
| 329 | 1.2.3.1.4.1.3 | **Column & Wall (L3)** | 18d | 2024-09-28 | 2024-10-18 |  |  |  |  | 0d | 0% |
| 330 | 1.2.3.1.4.1.3.1 | Reinforcement | 14d | 2024-09-28 | 2024-10-14 | 327 | 2024-09-28 | 2024-10-14 | 14d | 0d | 0% |
| 331 | 1.2.3.1.4.1.3.2 | Formwork | 10d | 2024-10-07 | 2024-10-17 | 330FS-7d | 2024-10-07 | 2024-10-17 | 10d | 0d | 0% |
| 332 | 1.2.3.1.4.1.3.3 | Concrete | 3d | 2024-10-16 | 2024-10-18 | 331FS-2d | 2024-10-16 | 2024-10-18 | 3d | 0d | 0% |
| 333 | 1.2.3.1.4.1.4 | Dismantle Propping | 3d | 2024-01-15 | 2024-01-17 | 367 | 2024-10-19 | 2024-10-22 | 3d | 0d | 0% |
| 334 | 1.2.3.1.4.2 | **Zone B** | 225d | 2024-02-02 | 2024-10-30 |  |  |  |  | 0d | 0% |
| 335 | 1.2.3.1.4.2.1 | **Beam & Slab (L3)** | 16d | 2024-09-21 | 2024-10-09 |  |  |  |  | 0d | 0% |
| 336 | 1.2.3.1.4.2.1.1 | Formwork | 10d | 2024-09-21 | 2024-10-02 | 325 |  |  |  | 0d | 0% |
| 337 | 1.2.3.1.4.2.1.2 | Reinforcement | 10d | 2024-09-27 | 2024-10-08 | 336FS-5d |  |  |  | 0d | 0% |
| 338 | 1.2.3.1.4.2.1.3 | Concrete | 3d | 2024-10-07 | 2024-10-09 | 337FS-2d |  |  |  | 0d | 0% |
| 339 | 1.2.3.1.4.2.2 | Post Tension Stressing | 2d | 2024-10-10 | 2024-10-11 | 338 |  |  |  | 0d | 0% |
| 340 | 1.2.3.1.4.2.3 | **Column & Wall (L3)** | 18d | 2024-10-10 | 2024-10-30 |  |  |  |  | 0d | 0% |
| 341 | 1.2.3.1.4.2.3.1 | Reinforcement | 14d | 2024-10-10 | 2024-10-25 | 338 |  |  |  | 0d | 0% |
| 342 | 1.2.3.1.4.2.3.2 | Formwork | 10d | 2024-10-18 | 2024-10-29 | 341FS-7d |  |  |  | 0d | 0% |
| 343 | 1.2.3.1.4.2.3.3 | Concrete | 3d | 2024-10-28 | 2024-10-30 | 342FS-2d |  |  |  | 0d | 0% |
| 344 | 1.2.3.1.4.2.4 | Dismantle Propping | 3d | 2024-02-02 | 2024-02-05 | 373 |  |  |  | 0d | 0% |
| 345 | 1.2.3.1.4.3 | Parapet Wall | 40d | 2024-08-21 | 2024-10-08 | 264 |  |  |  | 0d | 0% |
| 346 | 1.2.3.1.4.4 | Staircase | 50d | 2024-07-09 | 2024-09-05 | 281 |  |  |  | 0d | 0% |
| 347 | 1.2.3.1.4.5 | Car Park Ramp | 50d | 2024-07-09 | 2024-09-05 | 281 |  |  |  | 0d | 0% |
| 348 | 1.2.3.2 | **Tower** | 262d | 2024-01-02 | 2024-11-12 |  |  |  |  | 0d | 0% |
| 349 | 1.2.3.2.1 | **Level 3A** | 262d | 2024-01-02 | 2024-11-12 |  |  |  |  | 0d | 0% |
| 350 | 1.2.3.2.1.1 | **Zone A** | 252d | 2024-01-02 | 2024-10-30 |  |  |  |  | 0d | 0% |
| 351 | 1.2.3.2.1.1.1 | **Slab (L3A Zone A)** | 252d | 2024-01-02 | 2024-10-30 |  |  |  |  | 0d | 0% |
| 352 | 1.2.3.2.1.1.1.1 | Formwork | 10d | 2024-10-19 | 2024-10-30 | 332 |  |  |  | 0d | 0% |
| 353 | 1.2.3.2.1.1.1.2 | Reinforcement | 10d | 2024-01-02 | 2024-01-12 |  |  |  |  | 0d | 0% |
| 354 | 1.2.3.2.1.1.1.3 | Concrete | 1d | 2024-01-13 | 2024-01-13 | 353 |  |  |  | 0d | 0% |
| 355 | 1.2.3.2.1.1.1.4 | Dismantle Propping | 3d | 2024-02-02 | 2024-02-05 | 380 |  |  |  | 0d | 0% |

| ID | WBS | Task | Duration | Start | Finish | Predecessors | Baseline start | Baseline finish | Baseline duration | Total slack | %Planned |
| --- | --- | --- | --- | --- | --- | --- | --- | --- | --- | --- | --- |
| 356 | 1.2.3.2.1.2 | **Zone B** | 262d | 2024-01-02 | 2024-11-12 |  |  |  |  | 0d | 0% |
| 357 | 1.2.3.2.1.2.1 | **Slab (L3A Zone B)** | 262d | 2024-01-02 | 2024-11-12 |  |  |  |  | 0d | 0% |
| 358 | 1.2.3.2.1.2.1.1 | Formwork | 10d | 2024-11-01 | 2024-11-12 | 352 |  |  |  | 0d | 0% |
| 359 | 1.2.3.2.1.2.1.2 | Reinforcement | 10d | 2024-01-02 | 2024-01-12 |  |  |  |  | 0d | 0% |
| 360 | 1.2.3.2.1.2.1.3 | Concrete | 1d | 2024-01-13 | 2024-01-13 | 359 |  |  |  | 0d | 0% |
| 361 | 1.2.3.2.1.2.2 | Dismantle Propping | 3d | 2024-02-21 | 2024-02-23 | 386 |  |  |  | 0d | 0% |
| 362 | 1.2.3.2.2 | **Level 5** | 90d | 2024-01-02 | 2024-04-17 |  |  |  |  | 0d | 0% |
| 363 | 1.2.3.2.2.1 | **Zone A** | 46d | 2024-01-02 | 2024-02-23 |  |  |  |  | 0d | 0% |
| 364 | 1.2.3.2.2.1.1 | **Slab & Wall Below (L5 Zone A)** | 21d | 2024-01-02 | 2024-01-25 |  |  |  |  | 0d | 0% |
| 365 | 1.2.3.2.2.1.1.1 | Formwork | 10d | 2024-01-15 | 2024-01-25 | 354 | 2024-11-08 | 2024-11-19 | 10d | 0d | 0% |
| 366 | 1.2.3.2.2.1.1.2 | Reinforcement | 10d | 2024-01-02 | 2024-01-12 |  | 2024-11-14 | 2024-11-25 | 10d | 0d | 0% |
| 367 | 1.2.3.2.2.1.1.3 | Concrete | 1d | 2024-01-13 | 2024-01-13 | 366 | 2024-11-26 | 2024-11-26 | 1d | 0d | 0% |
| 368 | 1.2.3.2.2.1.2 | Dismantle Propping | 3d | 2024-02-21 | 2024-02-23 | 393 | 2025-01-06 | 2025-01-08 | 3d | 0d | 0% |
| 369 | 1.2.3.2.2.2 | **Zone B** | 79d | 2024-01-15 | 2024-04-17 |  |  |  |  | 0d | 0% |
| 370 | 1.2.3.2.2.2.1 | **Slab & Wall Below (L5 Zone B)** | 16d | 2024-01-15 | 2024-02-01 |  |  |  |  | 0d | 0% |
| 371 | 1.2.3.2.2.2.1.1 | Formwork | 10d | 2024-01-15 | 2024-01-25 | 360 | 2024-11-20 | 2024-11-30 | 10d | 0d | 0% |
| 372 | 1.2.3.2.2.2.1.2 | Reinforcement | 10d | 2024-01-20 | 2024-01-31 | 371FS-5d | 2024-11-26 | 2024-12-06 | 10d | 0d | 0% |
| 373 | 1.2.3.2.2.2.1.3 | Concrete | 1d | 2024-02-01 | 2024-02-01 | 372 | 2024-12-07 | 2024-12-07 | 1d | 0d | 0% |
| 374 | 1.2.3.2.2.2.2 | Dismantle Propping | 3d | 2024-04-15 | 2024-04-17 | 400 | 2025-03-01 | 2025-03-04 | 3d | 0d | 0% |
| 375 | 1.2.3.2.3 | **Level 6** | 70d | 2024-01-15 | 2024-04-04 |  |  |  |  | 0d | 0% |
| 376 | 1.2.3.2.3.1 | **Zone A** | 54d | 2024-01-15 | 2024-03-16 |  |  |  |  | 0d | 0% |
| 377 | 1.2.3.2.3.1.1 | **Slab & Wall Below (L6 Zone A)** | 16d | 2024-01-15 | 2024-02-01 |  |  |  |  | 0d | 0% |
| 378 | 1.2.3.2.3.1.1.1 | Formwork | 10d | 2024-01-15 | 2024-01-25 | 367 | 2024-11-27 | 2024-12-07 | 10d | 0d | 0% |
| 379 | 1.2.3.2.3.1.1.2 | Reinforcement | 10d | 2024-01-20 | 2024-01-31 | 378FS-5d | 2024-12-03 | 2024-12-14 | 10d | 0d | 0% |
| 380 | 1.2.3.2.3.1.1.3 | Concrete | 1d | 2024-02-01 | 2024-02-01 | 379 | 2024-12-16 | 2024-12-16 | 1d | 0d | 0% |
| 381 | 1.2.3.2.3.1.2 | Dismantle Propping | 3d | 2024-03-14 | 2024-03-16 | 415 | 2025-01-28 | 2025-02-01 | 3d | 0d | 0% |

| ID | WBS | Task | Duration | Start | Finish | Predecessors | Baseline start | Baseline finish | Baseline duration | Total slack | %Planned |
| --- | --- | --- | --- | --- | --- | --- | --- | --- | --- | --- | --- |
| 382 | 1.2.3.2.3.2 | **Zone B** | 54d | 2024-02-02 | 2024-04-04 |  |  |  |  | 0d | 0% |
| 383 | 1.2.3.2.3.2.1 | **Slab & Wall Below (L6 Zone B)** | 16d | 2024-02-02 | 2024-02-20 |  |  |  |  | 0d | 0% |
| 384 | 1.2.3.2.3.2.1.1 | Formwork | 10d | 2024-02-02 | 2024-02-13 | 373 | 2024-12-09 | 2024-12-20 | 10d | 0d | 0% |
| 385 | 1.2.3.2.3.2.1.2 | Reinforcement | 10d | 2024-02-08 | 2024-02-19 | 384FS-5d | 2024-12-16 | 2024-12-27 | 10d | 0d | 0% |
| 386 | 1.2.3.2.3.2.1.3 | Concrete | 1d | 2024-02-20 | 2024-02-20 | 385 | 2024-12-28 | 2024-12-28 | 1d | 0d | 0% |
| 387 | 1.2.3.2.3.2.2 | Dismantle Propping | 3d | 2024-04-02 | 2024-04-04 | 420 | 2025-02-12 | 2025-02-14 | 3d | 0d | 0% |
| 388 | 1.2.3.2.4 | **Level 7** | 60d | 2024-02-02 | 2024-04-13 |  |  |  |  | 0d | 0% |
| 389 | 1.2.3.2.4.1 | **Zone A** | 60d | 2024-02-02 | 2024-04-13 |  |  |  |  | 0d | 0% |
| 390 | 1.2.3.2.4.1.1 | **Slab & Wall Below (L7 Zone A)** | 16d | 2024-02-02 | 2024-02-20 |  |  |  |  | 0d | 0% |
| 391 | 1.2.3.2.4.1.1.1 | Formwork | 10d | 2024-02-02 | 2024-02-13 | 380 | 2024-12-17 | 2024-12-28 | 10d | 0d | 0% |
| 392 | 1.2.3.2.4.1.1.2 | Reinforcement | 10d | 2024-02-08 | 2024-02-19 | 391FS-5d | 2024-12-23 | 2025-01-03 | 10d | 0d | 0% |
| 393 | 1.2.3.2.4.1.1.3 | Concrete | 1d | 2024-02-20 | 2024-02-20 | 392 | 2025-01-04 | 2025-01-04 | 1d | 0d | 0% |
| 394 | 1.2.3.2.4.1.2 | Dismantle Propping | 3d | 2024-04-09 | 2024-04-13 | 429 | 2025-02-26 | 2025-02-28 | 3d | 0d | 0% |
| 395 | 1.2.3.2.4.2 | **Zone B** | 44d | 2024-02-21 | 2024-04-13 |  |  |  |  | 0d | 0% |
| 396 | 1.2.3.2.4.2.1 | **Slab & Wall Below (L7 Zone B)** | 16d | 2024-02-21 | 2024-03-09 |  |  |  |  | 0d | 0% |
| 397 | 1.2.3.2.4.2.1.1 | Formwork | 10d | 2024-02-21 | 2024-03-02 | 386 | 2024-12-30 | 2025-01-09 | 10d | 0d | 0% |
| 398 | 1.2.3.2.4.2.1.2 | Reinforcement | 10d | 2024-02-27 | 2024-03-08 | 397FS-5d | 2025-01-04 | 2025-01-15 | 10d | 0d | 0% |
| 399 | 1.2.3.2.4.2.1.3 | Concrete | 1d | 2024-03-09 | 2024-03-09 | 398 | 2025-01-16 | 2025-01-16 | 1d | 0d | 0% |
| 400 | 1.2.3.2.4.2.2 | Dismantle Propping | 3d | 2024-04-09 | 2024-04-13 | 429 | 2025-02-26 | 2025-02-28 | 3d | 0d | 0% |
| 401 | 1.2.3.2.5 | **Roof Beam** | 31d | 2024-02-21 | 2024-03-27 |  |  |  |  | 0d | 0% |
| 402 | 1.2.3.2.5.1 | **Zone A** | 17d | 2024-02-21 | 2024-03-11 |  |  |  |  | 0d | 0% |
| 403 | 1.2.3.2.5.1.1 | Formwork | 10d | 2024-02-21 | 2024-03-02 | 393 | 2025-01-06 | 2025-01-16 | 10d | 0d | 0% |
| 404 | 1.2.3.2.5.1.2 | Reinforcement | 10d | 2024-02-27 | 2024-03-08 | 403FS-5d | 2025-01-11 | 2025-01-22 | 10d | 0d | 0% |
| 405 | 1.2.3.2.5.1.3 | Concrete | 3d | 2024-03-08 | 2024-03-11 | 404FS-1d | 2025-01-22 | 2025-01-24 | 3d | 0d | 0% |

| ID | WBS | Task | Duration | Start | Finish | Predecessors | Baseline start | Baseline finish | Baseline duration | Total slack | %Planned |
| --- | --- | --- | --- | --- | --- | --- | --- | --- | --- | --- | --- |
| 406 | 1.2.3.2.5.2 | **Zone B** | 17d | 2024-03-08 | 2024-03-27 |  |  |  |  | 0d | 0% |
| 407 | 1.2.3.2.5.2.1 | Formwork | 10d | 2024-03-11 | 2024-03-21 | 399 | 2025-01-17 | 2025-01-28 | 10d | 0d | 0% |
| 408 | 1.2.3.2.5.2.2 | Reinforcement | 10d | 2024-03-16 | 2024-03-27 | 407FS-5d | 2025-01-23 | 2025-02-05 | 10d | 0d | 0% |
| 409 | 1.2.3.2.5.2.3 | Concrete | 3d | 2024-03-08 | 2024-03-11 | 404FS-1d | 2025-01-22 | 2025-01-24 | 3d | 0d | 0% |
| 410 | 1.2.3.2.6 | **RC Roof** | 35d | 2024-02-21 | 2024-04-01 |  |  |  |  | 0d | 0% |
| 411 | 1.2.3.2.6.1 | **Zone A** | 19d | 2024-02-21 | 2024-03-13 |  |  |  |  | 0d | 0% |
| 412 | 1.2.3.2.6.1.1 | **Beam& Slab (L4 Zone A)** | 19d | 2024-02-21 | 2024-03-13 |  |  |  |  | 0d | 0% |
| 413 | 1.2.3.2.6.1.1.1 | Formwork | 12d | 2024-02-21 | 2024-03-05 | 393 | 2025-01-06 | 2025-01-18 | 12d | 0d | 0% |
| 414 | 1.2.3.2.6.1.1.2 | Reinforcement | 12d | 2024-02-28 | 2024-03-12 | 413FS-6d | 2025-01-13 | 2025-01-25 | 12d | 0d | 0% |
| 415 | 1.2.3.2.6.1.1.3 | Concrete | 1d | 2024-03-13 | 2024-03-13 | 414 | 2025-01-27 | 2025-01-27 | 1d | 0d | 0% |
| 416 | 1.2.3.2.6.2 | **Zone B** | 19d | 2024-03-11 | 2024-04-01 |  |  |  |  | 0d | 0% |
| 417 | 1.2.3.2.6.2.1 | **Beam& Slab (L4 Zone A)** | 19d | 2024-03-11 | 2024-04-01 |  |  |  |  | 0d | 0% |
| 418 | 1.2.3.2.6.2.1.1 | Formwork | 12d | 2024-03-11 | 2024-03-23 | 399 | 2025-01-17 | 2025-02-01 | 12d | 0d | 0% |
| 419 | 1.2.3.2.6.2.1.2 | Reinforcement | 12d | 2024-03-18 | 2024-03-30 | 418FS-6d | 2025-01-24 | 2025-02-08 | 12d | 0d | 0% |
| 420 | 1.2.3.2.6.2.1.3 | Concrete | 1d | 2024-04-01 | 2024-04-01 | 419 | 2025-02-11 | 2025-02-11 | 1d | 0d | 0% |
| 421 | 1.2.3.2.7 | **LMR** | 22d | 2024-03-14 | 2024-04-08 |  |  |  |  | 0d | 0% |
| 422 | 1.2.3.2.7.1 | **Column& Wall (LMR Zone A)** | 11d | 2024-03-14 | 2024-03-26 |  |  |  |  | 0d | 0% |
| 423 | 1.2.3.2.7.1.1 | Formwork | 7d | 2024-03-14 | 2024-03-21 | 415 | 2025-01-28 | 2025-02-06 | 7d | 0d | 0% |
| 424 | 1.2.3.2.7.1.2 | Reinforcement | 7d | 2024-03-18 | 2024-03-25 | 423FS-4d | 2025-02-03 | 2025-02-11 | 7d | 0d | 0% |
| 425 | 1.2.3.2.7.1.3 | Concrete | 1d | 2024-03-26 | 2024-03-26 | 424 | 2025-02-12 | 2025-02-12 | 1d | 0d | 0% |
| 426 | 1.2.3.2.7.2 | **RC Roof** | 11d | 2024-03-27 | 2024-04-08 |  |  |  |  | 0d | 0% |
| 427 | 1.2.3.2.7.2.1 | Formwork | 7d | 2024-03-27 | 2024-04-03 | 425 | 2025-02-13 | 2025-02-20 | 7d | 0d | 0% |
| 428 | 1.2.3.2.7.2.2 | Reinforcement | 7d | 2024-03-30 | 2024-04-06 | 427FS-4d | 2025-02-17 | 2025-02-24 | 7d | 0d | 0% |
| 429 | 1.2.3.2.7.2.3 | Concrete | 1d | 2024-04-08 | 2024-04-08 | 428 | 2025-02-25 | 2025-02-25 | 1d | 0d | 0% |

| ID | WBS | Task | Duration | Start | Finish | Predecessors | Baseline start | Baseline finish | Baseline duration | Total slack | %Planned |
| --- | --- | --- | --- | --- | --- | --- | --- | --- | --- | --- | --- |
| 430 | 1.2.3.3 | **Roof Steel Structure** | 157d | 2023-10-12 | 2024-04-17 |  |  |  |  | 0d | 0% |
| 431 | 1.2.3.3.1 | Shop Drawing | 90d | 2023-10-12 | 2024-01-27 | 403FS-120d |  |  |  | 0d | 0% |
| 432 | 1.2.3.3.2 | Off-Site Fabrication | 60d | 2023-12-22 | 2024-03-02 | 403FS-60d |  |  |  | 0d | 0% |
| 433 | 1.2.3.3.3 | **On-Site Installation** | 20d | 2024-03-23 | 2024-04-17 |  |  |  |  | 0d | 0% |
| 434 | 1.2.3.3.3.1 | Zone A | 20d | 2024-03-23 | 2024-04-17 | 405FS+10d |  |  |  | 0d | 0% |
| 435 | 1.2.3.3.3.2 | Zone B | 20d | 2024-03-23 | 2024-04-17 | 409FS+10d |  |  |  | 0d | 0% |
| 436 | 1.2.3.4 | **Metal Roofing** | 20d | 2024-04-18 | 2024-05-11 |  |  |  |  | 0d | 0% |
| 437 | 1.2.3.4.1 | Zone A | 20d | 2024-04-18 | 2024-05-11 | 434 |  |  |  | 0d | 0% |
| 438 | 1.2.3.4.2 | Zone B | 20d | 2024-04-18 | 2024-05-11 | 435 |  |  |  | 0d | 0% |
| 439 | 1.2.4 | **Architecture Works** | 247d | 2024-01-02 | 2024-10-24 |  |  |  |  | 0d | 0% |
| 440 | 1.2.4.1 | **Floor Harderner** | 105d | 2024-05-24 | 2024-09-27 |  |  |  |  | 0d | 0% |
| 441 | 1.2.4.1.1 | Podium (Ground Floor) | 3d | 2024-05-24 | 2024-05-27 | 258FS-3d |  |  |  | 0d | 0% |
| 442 | 1.2.4.1.2 | Podium (Level 1) | 3d | 2024-07-05 | 2024-07-08 | 281FS-3d |  |  |  | 0d | 0% |
| 443 | 1.2.4.1.3 | Podium (Level 2) | 3d | 2024-08-14 | 2024-08-16 | 304FS-3d |  |  |  | 0d | 0% |
| 444 | 1.2.4.1.4 | Podium (Level 3) | 3d | 2024-09-25 | 2024-09-27 | 327FS-3d |  |  |  | 0d | 0% |
| 445 | 1.2.4.2 | **Rainwater Downpipe** | 224d | 2024-01-02 | 2024-09-27 |  |  |  |  | 0d | 0% |
| 446 | 1.2.4.2.1 | **1st Fix - Concealed Pipe Sleeves** | 223d | 2024-01-03 | 2024-09-27 |  |  |  |  | 0d | 0% |
| 447 | 1.2.4.2.1.1 | Podium (Ground Floor) | 10d | 2024-05-15 | 2024-05-27 | 258FS-10d | 2024-05-15 | 2024-05-27 | 10d | 0d | 0% |
| 448 | 1.2.4.2.1.2 | Podium (Level 1) | 10d | 2024-06-27 | 2024-07-08 | 281FS-10d | 2024-06-27 | 2024-07-08 | 10d | 0d | 0% |
| 449 | 1.2.4.2.1.3 | Podium (Level 2) | 10d | 2024-08-06 | 2024-08-16 | 304FS-10d | 2024-08-06 | 2024-08-16 | 10d | 0d | 0% |
| 450 | 1.2.4.2.1.4 | Podium (Level 3) | 10d | 2024-09-17 | 2024-09-27 | 327FS-10d | 2024-09-17 | 2024-09-27 | 10d | 0d | 0% |
| 451 | 1.2.4.2.1.5 | Tower (Level 3A) | 20d | 2024-01-03 | 2024-01-25 | 354FS-10d | 2024-10-26 | 2024-11-19 | 20d | 0d | 0% |
| 452 | 1.2.4.2.1.6 | Tower (Level 5) | 20d | 2024-01-03 | 2024-01-25 | 367FS-10d | 2024-11-15 | 2024-12-07 | 20d | 0d | 0% |
| 453 | 1.2.4.2.1.7 | Tower (Level 6) | 20d | 2024-01-22 | 2024-02-13 | 380FS-10d | 2024-12-04 | 2024-12-28 | 20d | 0d | 0% |
| 454 | 1.2.4.2.1.8 | Tower (Level 7) | 20d | 2024-02-09 | 2024-03-02 | 393FS-10d | 2024-12-24 | 2025-01-16 | 20d | 0d | 0% |
| 455 | 1.2.4.2.1.9 | Roof & LMR | 35d | 2024-02-29 | 2024-04-09 | 415FS-12d | 2025-01-14 | 2025-02-26 | 35d | 0d | 0% |

| ID | WBS | Task | Duration | Start | Finish | Predecessors | Baseline start | Baseline finish | Baseline duration | Total slack | %Planned |
| --- | --- | --- | --- | --- | --- | --- | --- | --- | --- | --- | --- |
| 456 | 1.2.4.2.2 | **2nd Fix - Piping, Down Pipe, Pipe Clip, Bracket** | 30d | 2024-01-02 | 2024-02-05 |  |  |  |  | 0d | 0% |
| 457 | 1.2.4.2.2.1 | Podium (Ground Floor) | 30d | 2024-01-02 | 2024-02-05 |  | 2024-01-02 | 2024-02-05 | 30d | 0d | 0% |
| 458 | 1.2.4.2.2.2 | Podium (Level 1) | 30d | 2024-01-02 | 2024-02-05 |  | 2024-01-02 | 2024-02-05 | 30d | 0d | 0% |
| 459 | 1.2.4.2.2.3 | Podium (Level 2) | 30d | 2024-01-02 | 2024-02-05 |  | 2024-01-02 | 2024-02-05 | 30d | 0d | 0% |
| 460 | 1.2.4.2.2.4 | Podium (Level 3) | 30d | 2024-01-02 | 2024-02-05 |  | 2024-01-02 | 2024-02-05 | 30d | 0d | 0% |
| 461 | 1.2.4.2.2.5 | Tower (Level 3A) | 30d | 2024-01-02 | 2024-02-05 |  | 2024-01-02 | 2024-02-05 | 30d | 0d | 0% |
| 462 | 1.2.4.2.2.6 | Tower (Level 5) | 30d | 2024-01-02 | 2024-02-05 |  | 2024-01-02 | 2024-02-05 | 30d | 0d | 0% |
| 463 | 1.2.4.2.2.7 | Tower (Level 6) | 30d | 2024-01-02 | 2024-02-05 |  | 2024-01-02 | 2024-02-05 | 30d | 0d | 0% |
| 464 | 1.2.4.2.2.8 | Tower (Level 7) | 30d | 2024-01-02 | 2024-02-05 |  | 2024-01-02 | 2024-02-05 | 30d | 0d | 0% |
| 465 | 1.2.4.2.2.9 | Roof & LMR | 30d | 2024-01-02 | 2024-02-05 |  | 2024-01-02 | 2024-02-05 | 30d | 0d | 0% |
| 466 | 1.2.4.2.3 | **Final Fix - UPVC Dome and Gutter** | 20d | 2024-01-02 | 2024-01-24 |  |  |  |  | 0d | 0% |
| 467 | 1.2.4.2.3.1 | Roof Zone A | 20d | 2024-01-02 | 2024-01-24 |  | 2024-01-02 | 2024-01-24 | 20d | 0d | 0% |
| 468 | 1.2.4.2.3.2 | Roof Zone B | 20d | 2024-01-02 | 2024-01-24 |  | 2024-01-02 | 2024-01-24 | 20d | 0d | 0% |
| 469 | 1.2.4.3 | **Brick Work** | 247d | 2024-01-02 | 2024-10-24 |  |  |  |  | 0d | 0% |
| 470 | 1.2.4.3.1 | Podium (Ground Floor) | 20d | 2024-08-21 | 2024-09-13 | 264 |  |  |  | 0d | 0% |
| 471 | 1.2.4.3.2 | Podium (Level 1) | 20d | 2024-10-02 | 2024-10-24 | 287 |  |  |  | 0d | 0% |
| 472 | 1.2.4.3.3 | Podium (Level 2) | 20d | 2024-01-18 | 2024-02-09 | 310 |  |  |  | 0d | 0% |
| 473 | 1.2.4.3.4 | Podium (Level 3) | 20d | 2024-01-18 | 2024-02-09 | 333 |  |  |  | 0d | 0% |
| 474 | 1.2.4.3.5 | Tower (Level 3A) | 20d | 2024-01-02 | 2024-01-24 |  |  |  |  | 0d | 0% |
| 475 | 1.2.4.3.6 | Tower (Level 5) | 20d | 2024-01-02 | 2024-01-24 |  |  |  |  | 0d | 0% |
| 476 | 1.2.4.3.7 | Tower (Level 6) | 20d | 2024-01-02 | 2024-01-24 |  |  |  |  | 0d | 0% |
| 477 | 1.2.4.3.8 | Tower (Level 7) | 20d | 2024-01-02 | 2024-01-24 |  |  |  |  | 0d | 0% |
| 478 | 1.2.4.3.9 | Roof & LMR | 20d | 2024-01-02 | 2024-01-24 |  |  |  |  | 0d | 0% |
| 479 | 1.2.4.4 | **Door Frame & Window Frame** | 20d | 2024-01-02 | 2024-01-24 |  |  |  |  | 0d | 0% |
| 480 | 1.2.4.4.1 | Podium (Ground Floor) | 20d | 2024-01-02 | 2024-01-24 |  | 2024-01-02 | 2024-01-24 | 20d | 0d | 0% |
| 481 | 1.2.4.4.2 | Podium (Level 1) | 20d | 2024-01-02 | 2024-01-24 |  | 2024-01-02 | 2024-01-24 | 20d | 0d | 0% |
| 482 | 1.2.4.4.3 | Podium (Level 2) | 20d | 2024-01-02 | 2024-01-24 |  | 2024-01-02 | 2024-01-24 | 20d | 0d | 0% |
| 483 | 1.2.4.4.4 | Podium (Level 3) | 20d | 2024-01-02 | 2024-01-24 |  | 2024-01-02 | 2024-01-24 | 20d | 0d | 0% |
| 484 | 1.2.4.4.5 | Tower (Level 3A) | 20d | 2024-01-02 | 2024-01-24 |  | 2024-01-02 | 2024-01-24 | 20d | 0d | 0% |
| 485 | 1.2.4.4.6 | Tower (Level 5) | 20d | 2024-01-02 | 2024-01-24 |  | 2024-01-02 | 2024-01-24 | 20d | 0d | 0% |
| 486 | 1.2.4.4.7 | Tower (Level 6) | 20d | 2024-01-02 | 2024-01-24 |  | 2024-01-02 | 2024-01-24 | 20d | 0d | 0% |
| 487 | 1.2.4.4.8 | Tower (Level 7) | 20d | 2024-01-02 | 2024-01-24 |  | 2024-01-02 | 2024-01-24 | 20d | 0d | 0% |
| 488 | 1.2.4.4.9 | Roof & LMR | 20d | 2024-01-02 | 2024-01-24 |  |  |  |  | 0d | 0% |

| ID | WBS | Task | Duration | Start | Finish | Baseline start | Baseline finish | Baseline duration | Total slack | %Planned |
| --- | --- | --- | --- | --- | --- | --- | --- | --- | --- | --- |
| 489 | 1.2.4.5 | **Skim Coat** | 20d | 2024-01-02 | 2024-01-24 |  |  |  | 0d | 0% |
| 490 | 1.2.4.5.1 | Podium (Ground Floor) | 20d | 2024-01-02 | 2024-01-24 | 2024-01-02 | 2024-01-24 | 20d | 0d | 0% |
| 491 | 1.2.4.5.2 | Podium (Level 1) | 20d | 2024-01-02 | 2024-01-24 | 2024-01-02 | 2024-01-24 | 20d | 0d | 0% |
| 492 | 1.2.4.5.3 | Podium (Level 2) | 20d | 2024-01-02 | 2024-01-24 | 2024-01-02 | 2024-01-24 | 20d | 0d | 0% |
| 493 | 1.2.4.5.4 | Podium (Level 3) | 20d | 2024-01-02 | 2024-01-24 | 2024-01-02 | 2024-01-24 | 20d | 0d | 0% |
| 494 | 1.2.4.5.5 | Tower (Level 3A) | 20d | 2024-01-02 | 2024-01-24 | 2024-01-02 | 2024-01-24 | 20d | 0d | 0% |
| 495 | 1.2.4.5.6 | Tower (Level 5) | 20d | 2024-01-02 | 2024-01-24 | 2024-01-02 | 2024-01-24 | 20d | 0d | 0% |
| 496 | 1.2.4.5.7 | Tower (Level 6) | 20d | 2024-01-02 | 2024-01-24 | 2024-01-02 | 2024-01-24 | 20d | 0d | 0% |
| 497 | 1.2.4.5.8 | Tower (Level 7) | 20d | 2024-01-02 | 2024-01-24 | 2024-01-02 | 2024-01-24 | 20d | 0d | 0% |
| 498 | 1.2.4.5.9 | Roof & LMR | 20d | 2024-01-02 | 2024-01-24 |  |  |  | 0d | 0% |
| 499 | 1.2.4.6 | **Internal Plastering** | 20d | 2024-01-02 | 2024-01-24 |  |  |  | 0d | 0% |
| 500 | 1.2.4.6.1 | Podium (Ground Floor) | 20d | 2024-01-02 | 2024-01-24 | 2024-01-02 | 2024-01-24 | 20d | 0d | 0% |
| 501 | 1.2.4.6.2 | Podium (Level 1) | 20d | 2024-01-02 | 2024-01-24 | 2024-01-02 | 2024-01-24 | 20d | 0d | 0% |
| 502 | 1.2.4.6.3 | Podium (Level 2) | 20d | 2024-01-02 | 2024-01-24 | 2024-01-02 | 2024-01-24 | 20d | 0d | 0% |
| 503 | 1.2.4.6.4 | Podium (Level 3) | 20d | 2024-01-02 | 2024-01-24 | 2024-01-02 | 2024-01-24 | 20d | 0d | 0% |
| 504 | 1.2.4.6.5 | Tower (Level 3A) | 20d | 2024-01-02 | 2024-01-24 | 2024-01-02 | 2024-01-24 | 20d | 0d | 0% |
| 505 | 1.2.4.6.6 | Tower (Level 5) | 20d | 2024-01-02 | 2024-01-24 | 2024-01-02 | 2024-01-24 | 20d | 0d | 0% |
| 506 | 1.2.4.6.7 | Tower (Level 6) | 20d | 2024-01-02 | 2024-01-24 | 2024-01-02 | 2024-01-24 | 20d | 0d | 0% |
| 507 | 1.2.4.6.8 | Tower (Level 7) | 20d | 2024-01-02 | 2024-01-24 | 2024-01-02 | 2024-01-24 | 20d | 0d | 0% |
| 508 | 1.2.4.6.9 | Roof & LMR | 20d | 2024-01-02 | 2024-01-24 |  |  |  | 0d | 0% |
| 509 | 1.2.4.7 | **External Plastering** | 20d | 2024-01-02 | 2024-01-24 |  |  |  | 0d | 0% |
| 510 | 1.2.4.7.1 | Podium (Ground Floor) | 20d | 2024-01-02 | 2024-01-24 | 2024-01-02 | 2024-01-24 | 20d | 0d | 0% |
| 511 | 1.2.4.7.2 | Podium (Level 1) | 20d | 2024-01-02 | 2024-01-24 | 2024-01-02 | 2024-01-24 | 20d | 0d | 0% |
| 512 | 1.2.4.7.3 | Podium (Level 2) | 20d | 2024-01-02 | 2024-01-24 | 2024-01-02 | 2024-01-24 | 20d | 0d | 0% |
| 513 | 1.2.4.7.4 | Podium (Level 3) | 20d | 2024-01-02 | 2024-01-24 | 2024-01-02 | 2024-01-24 | 20d | 0d | 0% |
| 514 | 1.2.4.7.5 | Tower (Level 3A) | 20d | 2024-01-02 | 2024-01-24 | 2024-01-02 | 2024-01-24 | 20d | 0d | 0% |
| 515 | 1.2.4.7.6 | Tower (Level 5) | 20d | 2024-01-02 | 2024-01-24 | 2024-01-02 | 2024-01-24 | 20d | 0d | 0% |
| 516 | 1.2.4.7.7 | Tower (Level 6) | 20d | 2024-01-02 | 2024-01-24 | 2024-01-02 | 2024-01-24 | 20d | 0d | 0% |
| 517 | 1.2.4.7.8 | Tower (Level 7) | 20d | 2024-01-02 | 2024-01-24 | 2024-01-02 | 2024-01-24 | 20d | 0d | 0% |
| 518 | 1.2.4.7.9 | Roof & LMR | 20d | 2024-01-02 | 2024-01-24 |  |  |  | 0d | 0% |

| ID | WBS | Task | Duration | Start | Finish | Baseline start | Baseline finish | Baseline duration | Total slack | %Planned |
| --- | --- | --- | --- | --- | --- | --- | --- | --- | --- | --- |
| 519 | 1.2.4.8 | **Waterproofing** | 20d | 2024-01-02 | 2024-01-24 |  |  |  | 0d | 0% |
| 520 | 1.2.4.8.1 | Podium (Ground Floor) | 20d | 2024-01-02 | 2024-01-24 | 2024-01-02 | 2024-01-24 | 20d | 0d | 0% |
| 521 | 1.2.4.8.2 | Podium (Level 1) | 20d | 2024-01-02 | 2024-01-24 | 2024-01-02 | 2024-01-24 | 20d | 0d | 0% |
| 522 | 1.2.4.8.3 | Podium (Level 2) | 20d | 2024-01-02 | 2024-01-24 | 2024-01-02 | 2024-01-24 | 20d | 0d | 0% |
| 523 | 1.2.4.8.4 | Podium (Level 3) | 20d | 2024-01-02 | 2024-01-24 | 2024-01-02 | 2024-01-24 | 20d | 0d | 0% |
| 524 | 1.2.4.8.5 | Tower (Level 3A) | 20d | 2024-01-02 | 2024-01-24 | 2024-01-02 | 2024-01-24 | 20d | 0d | 0% |
| 525 | 1.2.4.8.6 | Tower (Level 5) | 20d | 2024-01-02 | 2024-01-24 | 2024-01-02 | 2024-01-24 | 20d | 0d | 0% |
| 526 | 1.2.4.8.7 | Tower (Level 6) | 20d | 2024-01-02 | 2024-01-24 | 2024-01-02 | 2024-01-24 | 20d | 0d | 0% |
| 527 | 1.2.4.8.8 | Tower (Level 7) | 20d | 2024-01-02 | 2024-01-24 | 2024-01-02 | 2024-01-24 | 20d | 0d | 0% |
| 528 | 1.2.4.8.9 | Roof & LMR | 20d | 2024-01-02 | 2024-01-24 |  |  |  | 0d | 0% |
| 529 | 1.2.4.9 | **Screeding & MS Railing Staircase** | 20d | 2024-01-02 | 2024-01-24 |  |  |  | 0d | 0% |
| 530 | 1.2.4.9.1 | Podium (Ground Floor) | 20d | 2024-01-02 | 2024-01-24 | 2024-01-02 | 2024-01-24 | 20d | 0d | 0% |
| 531 | 1.2.4.9.2 | Podium (Level 1) | 20d | 2024-01-02 | 2024-01-24 | 2024-01-02 | 2024-01-24 | 20d | 0d | 0% |
| 532 | 1.2.4.9.3 | Podium (Level 2) | 20d | 2024-01-02 | 2024-01-24 | 2024-01-02 | 2024-01-24 | 20d | 0d | 0% |
| 533 | 1.2.4.9.4 | Podium (Level 3) | 20d | 2024-01-02 | 2024-01-24 | 2024-01-02 | 2024-01-24 | 20d | 0d | 0% |
| 534 | 1.2.4.9.5 | Tower (Level 3A) | 20d | 2024-01-02 | 2024-01-24 | 2024-01-02 | 2024-01-24 | 20d | 0d | 0% |
| 535 | 1.2.4.9.6 | Tower (Level 5) | 20d | 2024-01-02 | 2024-01-24 | 2024-01-02 | 2024-01-24 | 20d | 0d | 0% |
| 536 | 1.2.4.9.7 | Tower (Level 6) | 20d | 2024-01-02 | 2024-01-24 | 2024-01-02 | 2024-01-24 | 20d | 0d | 0% |
| 537 | 1.2.4.9.8 | Tower (Level 7) | 20d | 2024-01-02 | 2024-01-24 | 2024-01-02 | 2024-01-24 | 20d | 0d | 0% |
| 538 | 1.2.4.9.9 | Roof & LMR | 20d | 2024-01-02 | 2024-01-24 |  |  |  | 0d | 0% |
| 539 | 1.2.4.10 | **Tiling** | 20d | 2024-01-02 | 2024-01-24 |  |  |  | 0d | 0% |
| 540 | 1.2.4.10.1 | Podium (Ground Floor) | 20d | 2024-01-02 | 2024-01-24 | 2024-01-02 | 2024-01-24 | 20d | 0d | 0% |
| 541 | 1.2.4.10.2 | Podium (Level 1) | 20d | 2024-01-02 | 2024-01-24 | 2024-01-02 | 2024-01-24 | 20d | 0d | 0% |
| 542 | 1.2.4.10.3 | Podium (Level 2) | 20d | 2024-01-02 | 2024-01-24 | 2024-01-02 | 2024-01-24 | 20d | 0d | 0% |
| 543 | 1.2.4.10.4 | Podium (Level 3) | 20d | 2024-01-02 | 2024-01-24 | 2024-01-02 | 2024-01-24 | 20d | 0d | 0% |
| 544 | 1.2.4.10.5 | Tower (Level 3A) | 20d | 2024-01-02 | 2024-01-24 | 2024-01-02 | 2024-01-24 | 20d | 0d | 0% |
| 545 | 1.2.4.10.6 | Tower (Level 5) | 20d | 2024-01-02 | 2024-01-24 | 2024-01-02 | 2024-01-24 | 20d | 0d | 0% |
| 546 | 1.2.4.10.7 | Tower (Level 6) | 20d | 2024-01-02 | 2024-01-24 | 2024-01-02 | 2024-01-24 | 20d | 0d | 0% |
| 547 | 1.2.4.10.8 | Tower (Level 7) | 20d | 2024-01-02 | 2024-01-24 | 2024-01-02 | 2024-01-24 | 20d | 0d | 0% |
| 548 | 1.2.4.10.9 | Roof & LMR | 20d | 2024-01-02 | 2024-01-24 |  |  |  | 0d | 0% |

| ID | WBS | Task | Duration | Start | Finish | Baseline start | Baseline finish | Baseline duration | Total slack | %Planned |
| --- | --- | --- | --- | --- | --- | --- | --- | --- | --- | --- |
| 549 | 1.2.4.11 | **Ceiling** | 20d | 2024-01-02 | 2024-01-24 |  |  |  | 0d | 0% |
| 550 | 1.2.4.11.1 | Podium (Ground Floor) | 20d | 2024-01-02 | 2024-01-24 | 2024-01-02 | 2024-01-24 | 20d | 0d | 0% |
| 551 | 1.2.4.11.2 | Podium (Level 1) | 20d | 2024-01-02 | 2024-01-24 | 2024-01-02 | 2024-01-24 | 20d | 0d | 0% |
| 552 | 1.2.4.11.3 | Podium (Level 2) | 20d | 2024-01-02 | 2024-01-24 | 2024-01-02 | 2024-01-24 | 20d | 0d | 0% |
| 553 | 1.2.4.11.4 | Podium (Level 3) | 20d | 2024-01-02 | 2024-01-24 | 2024-01-02 | 2024-01-24 | 20d | 0d | 0% |
| 554 | 1.2.4.11.5 | Tower (Level 3A) | 20d | 2024-01-02 | 2024-01-24 | 2024-01-02 | 2024-01-24 | 20d | 0d | 0% |
| 555 | 1.2.4.11.6 | Tower (Level 5) | 20d | 2024-01-02 | 2024-01-24 | 2024-01-02 | 2024-01-24 | 20d | 0d | 0% |
| 556 | 1.2.4.11.7 | Tower (Level 6) | 20d | 2024-01-02 | 2024-01-24 | 2024-01-02 | 2024-01-24 | 20d | 0d | 0% |
| 557 | 1.2.4.11.8 | Tower (Level 7) | 20d | 2024-01-02 | 2024-01-24 | 2024-01-02 | 2024-01-24 | 20d | 0d | 0% |
| 558 | 1.2.4.11.9 | Roof & LMR | 20d | 2024-01-02 | 2024-01-24 |  |  |  | 0d | 0% |
| 559 | 1.2.4.12 | **Window Glazing** | 20d | 2024-01-02 | 2024-01-24 |  |  |  | 0d | 0% |
| 560 | 1.2.4.12.1 | Podium (Ground Floor) | 20d | 2024-01-02 | 2024-01-24 | 2024-01-02 | 2024-01-24 | 20d | 0d | 0% |
| 561 | 1.2.4.12.2 | Podium (Level 1) | 20d | 2024-01-02 | 2024-01-24 | 2024-01-02 | 2024-01-24 | 20d | 0d | 0% |
| 562 | 1.2.4.12.3 | Podium (Level 2) | 20d | 2024-01-02 | 2024-01-24 | 2024-01-02 | 2024-01-24 | 20d | 0d | 0% |
| 563 | 1.2.4.12.4 | Podium (Level 3) | 20d | 2024-01-02 | 2024-01-24 | 2024-01-02 | 2024-01-24 | 20d | 0d | 0% |
| 564 | 1.2.4.12.5 | Tower (Level 3A) | 20d | 2024-01-02 | 2024-01-24 | 2024-01-02 | 2024-01-24 | 20d | 0d | 0% |
| 565 | 1.2.4.12.6 | Tower (Level 5) | 20d | 2024-01-02 | 2024-01-24 | 2024-01-02 | 2024-01-24 | 20d | 0d | 0% |
| 566 | 1.2.4.12.7 | Tower (Level 6) | 20d | 2024-01-02 | 2024-01-24 | 2024-01-02 | 2024-01-24 | 20d | 0d | 0% |
| 567 | 1.2.4.12.8 | Tower (Level 7) | 20d | 2024-01-02 | 2024-01-24 | 2024-01-02 | 2024-01-24 | 20d | 0d | 0% |
| 568 | 1.2.4.13 | **Toilet Cubicle** | 20d | 2024-01-02 | 2024-01-24 |  |  |  | 0d | 0% |
| 569 | 1.2.4.13.1 | Facilitis Floor | 20d | 2024-01-02 | 2024-01-24 |  |  |  | 0d | 0% |
| 570 | 1.2.4.14 | **Door Leaf & Ironmongery** | 20d | 2024-01-02 | 2024-01-24 |  |  |  | 0d | 0% |
| 571 | 1.2.4.14.1 | Podium (Ground Floor) | 20d | 2024-01-02 | 2024-01-24 | 2024-01-02 | 2024-01-24 | 20d | 0d | 0% |
| 572 | 1.2.4.14.2 | Podium (Level 1) | 20d | 2024-01-02 | 2024-01-24 | 2024-01-02 | 2024-01-24 | 20d | 0d | 0% |
| 573 | 1.2.4.14.3 | Podium (Level 2) | 20d | 2024-01-02 | 2024-01-24 | 2024-01-02 | 2024-01-24 | 20d | 0d | 0% |
| 574 | 1.2.4.14.4 | Podium (Level 3) | 20d | 2024-01-02 | 2024-01-24 | 2024-01-02 | 2024-01-24 | 20d | 0d | 0% |
| 575 | 1.2.4.14.5 | Tower (Level 3A) | 20d | 2024-01-02 | 2024-01-24 | 2024-01-02 | 2024-01-24 | 20d | 0d | 0% |
| 576 | 1.2.4.14.6 | Tower (Level 5) | 20d | 2024-01-02 | 2024-01-24 | 2024-01-02 | 2024-01-24 | 20d | 0d | 0% |
| 577 | 1.2.4.14.7 | Tower (Level 6) | 20d | 2024-01-02 | 2024-01-24 | 2024-01-02 | 2024-01-24 | 20d | 0d | 0% |
| 578 | 1.2.4.14.8 | Tower (Level 7) | 20d | 2024-01-02 | 2024-01-24 | 2024-01-02 | 2024-01-24 | 20d | 0d | 0% |
| 579 | 1.2.4.14.9 | Roof & LMR | 20d | 2024-01-02 | 2024-01-24 |  |  |  | 0d | 0% |

| ID | WBS | Task | Duration | Start | Finish | Baseline start | Baseline finish | Baseline duration | Total slack | %Planned |
| --- | --- | --- | --- | --- | --- | --- | --- | --- | --- | --- |
| 580 | 1.2.4.15 | **Painting** | 20d | 2024-01-02 | 2024-01-24 |  |  |  | 0d | 0% |
| 581 | 1.2.4.15.1 | **Painting (Base Coat & 1st Coat)** | 20d | 2024-01-02 | 2024-01-24 |  |  |  | 0d | 0% |
| 582 | 1.2.4.15.1.1 | Podium (Ground Floor) | 20d | 2024-01-02 | 2024-01-24 | 2024-01-02 | 2024-01-24 | 20d | 0d | 0% |
| 583 | 1.2.4.15.1.2 | Podium (Level 1) | 20d | 2024-01-02 | 2024-01-24 | 2024-01-02 | 2024-01-24 | 20d | 0d | 0% |
| 584 | 1.2.4.15.1.3 | Podium (Level 2) | 20d | 2024-01-02 | 2024-01-24 | 2024-01-02 | 2024-01-24 | 20d | 0d | 0% |
| 585 | 1.2.4.15.1.4 | Podium (Level 3) | 20d | 2024-01-02 | 2024-01-24 | 2024-01-02 | 2024-01-24 | 20d | 0d | 0% |
| 586 | 1.2.4.15.1.5 | Tower (Level 3A) | 20d | 2024-01-02 | 2024-01-24 | 2024-01-02 | 2024-01-24 | 20d | 0d | 0% |
| 587 | 1.2.4.15.1.6 | Tower (Level 5) | 20d | 2024-01-02 | 2024-01-24 | 2024-01-02 | 2024-01-24 | 20d | 0d | 0% |
| 588 | 1.2.4.15.1.7 | Tower (Level 6) | 20d | 2024-01-02 | 2024-01-24 | 2024-01-02 | 2024-01-24 | 20d | 0d | 0% |
| 589 | 1.2.4.15.1.8 | Tower (Level 7) | 20d | 2024-01-02 | 2024-01-24 | 2024-01-02 | 2024-01-24 | 20d | 0d | 0% |
| 590 | 1.2.4.15.1.9 | Roof & LMR | 20d | 2024-01-02 | 2024-01-24 |  |  |  | 0d | 0% |
| 591 | 1.2.4.15.2 | **Painting (Final Coat)** | 20d | 2024-01-02 | 2024-01-24 |  |  |  | 0d | 0% |
| 592 | 1.2.4.15.2.1 | Podium (Ground Floor) | 20d | 2024-01-02 | 2024-01-24 | 2024-01-02 | 2024-01-24 | 20d | 0d | 0% |
| 593 | 1.2.4.15.2.2 | Podium (Level 1) | 20d | 2024-01-02 | 2024-01-24 | 2024-01-02 | 2024-01-24 | 20d | 0d | 0% |
| 594 | 1.2.4.15.2.3 | Podium (Level 2) | 20d | 2024-01-02 | 2024-01-24 | 2024-01-02 | 2024-01-24 | 20d | 0d | 0% |
| 595 | 1.2.4.15.2.4 | Podium (Level 3) | 20d | 2024-01-02 | 2024-01-24 | 2024-01-02 | 2024-01-24 | 20d | 0d | 0% |
| 596 | 1.2.4.15.2.5 | Tower (Level 3A) | 20d | 2024-01-02 | 2024-01-24 | 2024-01-02 | 2024-01-24 | 20d | 0d | 0% |
| 597 | 1.2.4.15.2.6 | Tower (Level 5) | 20d | 2024-01-02 | 2024-01-24 | 2024-01-02 | 2024-01-24 | 20d | 0d | 0% |
| 598 | 1.2.4.15.2.7 | Tower (Level 6) | 20d | 2024-01-02 | 2024-01-24 | 2024-01-02 | 2024-01-24 | 20d | 0d | 0% |
| 599 | 1.2.4.15.2.8 | Tower (Level 7) | 20d | 2024-01-02 | 2024-01-24 | 2024-01-02 | 2024-01-24 | 20d | 0d | 0% |
| 600 | 1.2.4.15.2.9 | Roof & LMR | 20d | 2024-01-02 | 2024-01-24 |  |  |  | 0d | 0% |
| 601 | 1.2.4.15.3 | **Painting (External)** | 20d | 2024-01-02 | 2024-01-24 |  |  |  | 0d | 0% |
| 602 | 1.2.4.15.3.1 | Left Side | 20d | 2024-01-02 | 2024-01-24 | 2024-01-02 | 2024-01-24 | 20d | 0d | 0% |
| 603 | 1.2.4.15.3.2 | Right Side | 20d | 2024-01-02 | 2024-01-24 | 2024-01-02 | 2024-01-24 | 20d | 0d | 0% |
| 604 | 1.2.4.15.3.3 | Front Side | 20d | 2024-01-02 | 2024-01-24 | 2024-01-02 | 2024-01-24 | 20d | 0d | 0% |
| 605 | 1.2.4.15.3.4 | Rear Side | 20d | 2024-01-02 | 2024-01-24 | 2024-01-02 | 2024-01-24 | 20d | 0d | 0% |

| ID | WBS | Task | Type | Duration | Start | Finish | Baseline start | Baseline finish | Baseline duration | Total slack | %Planned |
| --- | --- | --- | --- | --- | --- | --- | --- | --- | --- | --- | --- |
| 606 | 1.2.4.16 | **Facilitis Floor** |  | 30d | 2024-01-02 | 2024-02-05 |  |  |  | 0d | 0% |
| 607 | 1.2.4.16.1 | Management Office |  | 30d | 2024-01-02 | 2024-02-05 |  |  |  | 0d | 0% |
| 608 | 1.2.4.16.2 | Kindergarten |  | 30d | 2024-01-02 | 2024-02-05 |  |  |  | 0d | 0% |
| 609 | 1.2.4.16.3 | Toilet Male & Female Toilet & Prayer Room |  | 30d | 2024-01-02 | 2024-02-05 |  |  |  | 0d | 0% |
| 610 | 1.2.4.16.4 | Badminton Court |  | 30d | 2024-01-02 | 2024-02-05 |  |  |  | 0d | 0% |
| 611 | 1.2.4.17 | Refuse Room Centre |  | 30d | 2024-01-02 | 2024-02-05 |  |  |  | 0d | 0% |
| 612 | 1.2.4.18 | Car Park Parking Marking |  | 40d | 2024-01-02 | 2024-02-16 |  |  |  | 0d | 0% |
| 613 | 1.2.4.19 | Car Park Column Guard |  | 40d | 2024-01-02 | 2024-02-16 |  |  |  | 0d | 0% |
| 614 | 1.2.4.20 | Building Signages |  | 30d | 2024-01-02 | 2024-02-05 |  |  |  | 0d | 0% |
| 615 | 1.2.5 | Miscellaneous | manual | 30d | 2024-01-02 | 2024-02-05 |  |  |  |  | 0% |
| 616 | 1.2.6 | **M&E Works** |  | 180d | 2024-01-02 | 2024-08-05 |  |  |  | 0d | 0% |
| 617 | 1.2.6.1 | **Electrical & ELV Services** |  | 60d | 2024-01-02 | 2024-03-11 |  |  |  | 0d | 0% |
| 618 | 1.2.6.1.1 | **1st Fix - Electrical & ELV Conduit Installation** |  | 20d | 2024-01-02 | 2024-01-24 |  |  |  | 0d | 0% |
| 619 | 1.2.6.1.1.1 | **Electrical Concealed Piping Works** |  | 20d | 2024-01-02 | 2024-01-24 |  |  |  | 0d | 0% |
| 620 | 1.2.6.1.1.1.1 | Podium (Ground Floor) |  | 20d | 2024-01-02 | 2024-01-24 |  |  |  | 0d | 0% |
| 621 | 1.2.6.1.1.1.2 | Podium (Level 1) |  | 20d | 2024-01-02 | 2024-01-24 |  |  |  | 0d | 0% |
| 622 | 1.2.6.1.1.1.3 | Podium (Level 2) |  | 20d | 2024-01-02 | 2024-01-24 |  |  |  | 0d | 0% |
| 623 | 1.2.6.1.1.1.4 | Podium (Level 3) |  | 20d | 2024-01-02 | 2024-01-24 |  |  |  | 0d | 0% |
| 624 | 1.2.6.1.1.1.5 | Tower (Level 3A) |  | 20d | 2024-01-02 | 2024-01-24 |  |  |  | 0d | 0% |
| 625 | 1.2.6.1.1.1.6 | Tower (Level 5) |  | 20d | 2024-01-02 | 2024-01-24 |  |  |  | 0d | 0% |
| 626 | 1.2.6.1.1.1.7 | Tower (Level 6) |  | 20d | 2024-01-02 | 2024-01-24 |  |  |  | 0d | 0% |
| 627 | 1.2.6.1.1.1.8 | Tower (Level 7) |  | 20d | 2024-01-02 | 2024-01-24 |  |  |  | 0d | 0% |
| 628 | 1.2.6.1.1.1.9 | Roof & LMR |  | 20d | 2024-01-02 | 2024-01-24 |  |  |  | 0d | 0% |
| 629 | 1.2.6.1.1.2 | **ELV Concealed Piping Works** |  | 20d | 2024-01-02 | 2024-01-24 |  |  |  | 0d | 0% |
| 630 | 1.2.6.1.1.2.1 | Podium (Ground Floor) |  | 20d | 2024-01-02 | 2024-01-24 | 2024-01-02 | 2024-01-24 | 20d | 0d | 0% |
| 631 | 1.2.6.1.1.2.2 | Podium (Level 1) |  | 20d | 2024-01-02 | 2024-01-24 | 2024-01-02 | 2024-01-24 | 20d | 0d | 0% |
| 632 | 1.2.6.1.1.2.3 | Podium (Level 2) |  | 20d | 2024-01-02 | 2024-01-24 | 2024-01-02 | 2024-01-24 | 20d | 0d | 0% |
| 633 | 1.2.6.1.1.2.4 | Podium (Level 3) |  | 20d | 2024-01-02 | 2024-01-24 | 2024-01-02 | 2024-01-24 | 20d | 0d | 0% |
| 634 | 1.2.6.1.1.2.5 | Tower (Level 3A) |  | 20d | 2024-01-02 | 2024-01-24 | 2024-01-02 | 2024-01-24 | 20d | 0d | 0% |
| 635 | 1.2.6.1.1.2.6 | Tower (Level 5) |  | 20d | 2024-01-02 | 2024-01-24 | 2024-01-02 | 2024-01-24 | 20d | 0d | 0% |
| 636 | 1.2.6.1.1.2.7 | Tower (Level 6) |  | 20d | 2024-01-02 | 2024-01-24 | 2024-01-02 | 2024-01-24 | 20d | 0d | 0% |
| 637 | 1.2.6.1.1.2.8 | Tower (Level 7) |  | 20d | 2024-01-02 | 2024-01-24 | 2024-01-02 | 2024-01-24 | 20d | 0d | 0% |
| 638 | 1.2.6.1.1.2.9 | Roof & LMR |  | 20d | 2024-01-02 | 2024-01-24 | 2024-01-02 | 2024-01-24 | 20d | 0d | 0% |

| ID | WBS | Task | Duration | Start | Finish | Baseline start | Baseline finish | Baseline duration | Total slack | Constraint | %Planned |
| --- | --- | --- | --- | --- | --- | --- | --- | --- | --- | --- | --- |
| 639 | 1.2.6.1.2 | **2nd Fix- Electrical Main Buidling & ELV System** | 20d | 2024-01-02 | 2024-01-24 |  |  |  | 0d |  | 0% |
| 640 | 1.2.6.1.2.1 | **Electrical- Trunking, Cable Laying** | 20d | 2024-01-02 | 2024-01-24 |  |  |  | 0d |  | 0% |
| 641 | 1.2.6.1.2.1.1 | Podium (Ground Floor) | 20d | 2024-01-02 | 2024-01-24 | 2024-01-02 | 2024-01-24 | 20d | 0d |  | 0% |
| 642 | 1.2.6.1.2.1.2 | Podium (Level 1) | 20d | 2024-01-02 | 2024-01-24 | 2024-01-02 | 2024-01-24 | 20d | 0d |  | 0% |
| 643 | 1.2.6.1.2.1.3 | Podium (Level 2) | 20d | 2024-01-02 | 2024-01-24 | 2024-01-02 | 2024-01-24 | 20d | 0d |  | 0% |
| 644 | 1.2.6.1.2.1.4 | Podium (Level 3) | 20d | 2024-01-02 | 2024-01-24 | 2024-01-02 | 2024-01-24 | 20d | 0d |  | 0% |
| 645 | 1.2.6.1.2.1.5 | Tower (Level 3A) | 20d | 2024-01-02 | 2024-01-24 | 2024-01-02 | 2024-01-24 | 20d | 0d |  | 0% |
| 646 | 1.2.6.1.2.1.6 | Tower (Level 5) | 20d | 2024-01-02 | 2024-01-24 | 2024-01-02 | 2024-01-24 | 20d | 0d |  | 0% |
| 647 | 1.2.6.1.2.1.7 | Tower (Level 6) | 20d | 2024-01-02 | 2024-01-24 | 2024-01-02 | 2024-01-24 | 20d | 0d |  | 0% |
| 648 | 1.2.6.1.2.1.8 | Tower (Level 7) | 20d | 2024-01-02 | 2024-01-24 | 2024-01-02 | 2024-01-24 | 20d | 0d |  | 0% |
| 649 | 1.2.6.1.2.1.9 | Roof & LMR | 20d | 2024-01-02 | 2024-01-24 | 2024-01-02 | 2024-01-24 | 20d | 0d |  | 0% |
| 650 | 1.2.6.1.2.2 | **ELV- Cabling Routings & Earthing Points** | 20d | 2024-01-02 | 2024-01-24 |  |  |  | 0d |  | 0% |
| 651 | 1.2.6.1.2.2.1 | Podium (Ground Floor) | 20d | 2024-01-02 | 2024-01-24 | 2024-01-02 | 2024-01-24 | 20d | 0d |  | 0% |
| 652 | 1.2.6.1.2.2.2 | Podium (Level 1) | 20d | 2024-01-02 | 2024-01-24 | 2024-01-02 | 2024-01-24 | 20d | 0d |  | 0% |
| 653 | 1.2.6.1.2.2.3 | Podium (Level 2) | 20d | 2024-01-02 | 2024-01-24 | 2024-01-02 | 2024-01-24 | 20d | 0d |  | 0% |
| 654 | 1.2.6.1.2.2.4 | Podium (Level 3) | 20d | 2024-01-02 | 2024-01-24 | 2024-01-02 | 2024-01-24 | 20d | 0d |  | 0% |
| 655 | 1.2.6.1.2.2.5 | Tower (Level 3A) | 20d | 2024-01-02 | 2024-01-24 | 2024-01-02 | 2024-01-24 | 20d | 0d |  | 0% |
| 656 | 1.2.6.1.2.2.6 | Tower (Level 5) | 20d | 2024-01-02 | 2024-01-24 | 2024-01-02 | 2024-01-24 | 20d | 0d |  | 0% |
| 657 | 1.2.6.1.2.2.7 | Tower (Level 6) | 20d | 2024-01-02 | 2024-01-24 | 2024-01-02 | 2024-01-24 | 20d | 0d |  | 0% |
| 658 | 1.2.6.1.2.2.8 | Tower (Level 7) | 20d | 2024-01-02 | 2024-01-24 | 2024-01-02 | 2024-01-24 | 20d | 0d |  | 0% |
| 659 | 1.2.6.1.2.2.9 | Roof & LMR | 20d | 2024-01-02 | 2024-01-24 | 2024-01-02 | 2024-01-24 | 20d | 0d | finish no earlier than 2024-01-24 | 0% |
| 660 | 1.2.6.1.3 | **Final Fix - Switches, Isolator & Distributor Board** | 20d | 2024-01-02 | 2024-01-24 |  |  |  | 0d |  | 0% |
| 661 | 1.2.6.1.3.1 | **Switches, Isolator & Distributor Board** | 20d | 2024-01-02 | 2024-01-24 |  |  |  | 0d |  | 0% |
| 662 | 1.2.6.1.3.1.1 | Podium (Ground Floor) | 20d | 2024-01-02 | 2024-01-24 | 2024-01-02 | 2024-01-24 | 20d | 0d |  | 0% |
| 663 | 1.2.6.1.3.1.2 | Podium (Level 1) | 20d | 2024-01-02 | 2024-01-24 | 2024-01-02 | 2024-01-24 | 20d | 0d |  | 0% |
| 664 | 1.2.6.1.3.1.3 | Podium (Level 2) | 20d | 2024-01-02 | 2024-01-24 | 2024-01-02 | 2024-01-24 | 20d | 0d |  | 0% |
| 665 | 1.2.6.1.3.1.4 | Podium (Level 3) | 20d | 2024-01-02 | 2024-01-24 | 2024-01-02 | 2024-01-24 | 20d | 0d |  | 0% |
| 666 | 1.2.6.1.3.1.5 | Tower (Level 3A) | 20d | 2024-01-02 | 2024-01-24 | 2024-01-02 | 2024-01-24 | 20d | 0d |  | 0% |
| 667 | 1.2.6.1.3.1.6 | Tower (Level 5) | 20d | 2024-01-02 | 2024-01-24 | 2024-01-02 | 2024-01-24 | 20d | 0d |  | 0% |
| 668 | 1.2.6.1.3.1.7 | Tower (Level 6) | 20d | 2024-01-02 | 2024-01-24 | 2024-01-02 | 2024-01-24 | 20d | 0d |  | 0% |
| 669 | 1.2.6.1.3.1.8 | Tower (Level 7) | 20d | 2024-01-02 | 2024-01-24 | 2024-01-02 | 2024-01-24 | 20d | 0d |  | 0% |
| 670 | 1.2.6.1.3.1.9 | Roof & LMR | 20d | 2024-01-02 | 2024-01-24 | 2024-01-02 | 2024-01-24 | 20d | 0d |  | 0% |

| ID | WBS | Task | Duration | Start | Finish | Baseline start | Baseline finish | Baseline duration | Total slack | %Planned |
| --- | --- | --- | --- | --- | --- | --- | --- | --- | --- | --- |
| 671 | 1.2.6.1.3.2 | **Lighting Arrestor & Lighting Tape Accesorries** | 20d | 2024-01-02 | 2024-01-24 |  |  |  | 0d | 0% |
| 672 | 1.2.6.1.3.2.1 | Podium (Ground Floor) | 20d | 2024-01-02 | 2024-01-24 | 2024-01-02 | 2024-01-24 | 20d | 0d | 0% |
| 673 | 1.2.6.1.3.2.2 | Podium (Level 1) | 20d | 2024-01-02 | 2024-01-24 | 2024-01-02 | 2024-01-24 | 20d | 0d | 0% |
| 674 | 1.2.6.1.3.2.3 | Podium (Level 2) | 20d | 2024-01-02 | 2024-01-24 | 2024-01-02 | 2024-01-24 | 20d | 0d | 0% |
| 675 | 1.2.6.1.3.2.4 | Podium (Level 3) | 20d | 2024-01-02 | 2024-01-24 | 2024-01-02 | 2024-01-24 | 20d | 0d | 0% |
| 676 | 1.2.6.1.3.2.5 | Tower (Level 3A) | 20d | 2024-01-02 | 2024-01-24 | 2024-01-02 | 2024-01-24 | 20d | 0d | 0% |
| 677 | 1.2.6.1.3.2.6 | Tower (Level 5) | 20d | 2024-01-02 | 2024-01-24 | 2024-01-02 | 2024-01-24 | 20d | 0d | 0% |
| 678 | 1.2.6.1.3.2.7 | Tower (Level 6) | 20d | 2024-01-02 | 2024-01-24 | 2024-01-02 | 2024-01-24 | 20d | 0d | 0% |
| 679 | 1.2.6.1.3.2.8 | Tower (Level 7) | 20d | 2024-01-02 | 2024-01-24 | 2024-01-02 | 2024-01-24 | 20d | 0d | 0% |
| 680 | 1.2.6.1.3.2.9 | Roof & LMR | 20d | 2024-01-02 | 2024-01-24 | 2024-01-02 | 2024-01-24 | 20d | 0d | 0% |
| 681 | 1.2.6.1.4 | **Manhole** | 60d | 2024-01-02 | 2024-03-11 |  |  |  | 0d | 0% |
| 682 | 1.2.6.1.4.1 | Electrical Manhole | 60d | 2024-01-02 | 2024-03-11 | 2024-01-02 | 2024-03-11 | 60d | 0d | 0% |
| 683 | 1.2.6.1.4.2 | ELV Manhole | 60d | 2024-01-02 | 2024-03-11 | 2024-01-02 | 2024-03-11 | 60d | 0d | 0% |
| 684 | 1.2.6.2 | **Cold Water and Sanitary Plumbing Services** | 20d | 2024-01-02 | 2024-01-24 |  |  |  | 0d | 0% |
| 685 | 1.2.6.2.1 | **1st Fix- CWSP Concealed Pipe Sleeve Installation** | 20d | 2024-01-02 | 2024-01-24 |  |  |  | 0d | 0% |
| 686 | 1.2.6.2.1.1 | Podium (Ground Floor) | 20d | 2024-01-02 | 2024-01-24 | 2024-01-02 | 2024-01-24 | 20d | 0d | 0% |
| 687 | 1.2.6.2.1.2 | Podium (Level 1) | 20d | 2024-01-02 | 2024-01-24 | 2024-01-02 | 2024-01-24 | 20d | 0d | 0% |
| 688 | 1.2.6.2.1.3 | Podium (Level 2) | 20d | 2024-01-02 | 2024-01-24 | 2024-01-02 | 2024-01-24 | 20d | 0d | 0% |
| 689 | 1.2.6.2.1.4 | Podium (Level 3) | 20d | 2024-01-02 | 2024-01-24 | 2024-01-02 | 2024-01-24 | 20d | 0d | 0% |
| 690 | 1.2.6.2.1.5 | Tower (Level 3A) | 20d | 2024-01-02 | 2024-01-24 | 2024-01-02 | 2024-01-24 | 20d | 0d | 0% |
| 691 | 1.2.6.2.1.6 | Tower (Level 5) | 20d | 2024-01-02 | 2024-01-24 | 2024-01-02 | 2024-01-24 | 20d | 0d | 0% |
| 692 | 1.2.6.2.1.7 | Tower (Level 6) | 20d | 2024-01-02 | 2024-01-24 | 2024-01-02 | 2024-01-24 | 20d | 0d | 0% |
| 693 | 1.2.6.2.1.8 | Tower (Level 7) | 20d | 2024-01-02 | 2024-01-24 | 2024-01-02 | 2024-01-24 | 20d | 0d | 0% |
| 694 | 1.2.6.2.1.9 | Roof & LMR | 20d | 2024-01-02 | 2024-01-24 | 2024-01-02 | 2024-01-24 | 20d | 0d | 0% |

| ID | WBS | Task | Duration | Start | Finish | Baseline start | Baseline finish | Baseline duration | Total slack | %Planned |
| --- | --- | --- | --- | --- | --- | --- | --- | --- | --- | --- |
| 695 | 1.2.6.2.2 | **2nd Fix- CWSP Piping Routing** | 20d | 2024-01-02 | 2024-01-24 |  |  |  | 0d | 0% |
| 696 | 1.2.6.2.2.1 | Podium (Ground Floor) | 20d | 2024-01-02 | 2024-01-24 | 2024-01-02 | 2024-01-24 | 20d | 0d | 0% |
| 697 | 1.2.6.2.2.2 | Podium (Level 1) | 20d | 2024-01-02 | 2024-01-24 | 2024-01-02 | 2024-01-24 | 20d | 0d | 0% |
| 698 | 1.2.6.2.2.3 | Podium (Level 2) | 20d | 2024-01-02 | 2024-01-24 | 2024-01-02 | 2024-01-24 | 20d | 0d | 0% |
| 699 | 1.2.6.2.2.4 | Podium (Level 3) | 20d | 2024-01-02 | 2024-01-24 | 2024-01-02 | 2024-01-24 | 20d | 0d | 0% |
| 700 | 1.2.6.2.2.5 | Tower (Level 3A) | 20d | 2024-01-02 | 2024-01-24 | 2024-01-02 | 2024-01-24 | 20d | 0d | 0% |
| 701 | 1.2.6.2.2.6 | Tower (Level 5) | 20d | 2024-01-02 | 2024-01-24 | 2024-01-02 | 2024-01-24 | 20d | 0d | 0% |
| 702 | 1.2.6.2.2.7 | Tower (Level 6) | 20d | 2024-01-02 | 2024-01-24 | 2024-01-02 | 2024-01-24 | 20d | 0d | 0% |
| 703 | 1.2.6.2.2.8 | Tower (Level 7) | 20d | 2024-01-02 | 2024-01-24 | 2024-01-02 | 2024-01-24 | 20d | 0d | 0% |
| 704 | 1.2.6.2.2.9 | Roof & LMR | 20d | 2024-01-02 | 2024-01-24 | 2024-01-02 | 2024-01-24 | 20d | 0d | 0% |
| 705 | 1.2.6.2.3 | **Final Fix - Installation Sanitary Wares Fittings** | 20d | 2024-01-02 | 2024-01-24 |  |  |  | 0d | 0% |
| 706 | 1.2.6.2.3.1 | **Installation Sanitary Wares Fittings** | 20d | 2024-01-02 | 2024-01-24 |  |  |  | 0d | 0% |
| 707 | 1.2.6.2.3.1.1 | Podium (Ground Floor) | 20d | 2024-01-02 | 2024-01-24 | 2024-01-02 | 2024-01-24 | 20d | 0d | 0% |
| 708 | 1.2.6.2.3.1.2 | Podium (Level 1) | 20d | 2024-01-02 | 2024-01-24 | 2024-01-02 | 2024-01-24 | 20d | 0d | 0% |
| 709 | 1.2.6.2.3.1.3 | Podium (Level 2) | 20d | 2024-01-02 | 2024-01-24 | 2024-01-02 | 2024-01-24 | 20d | 0d | 0% |
| 710 | 1.2.6.2.3.1.4 | Podium (Level 3) | 20d | 2024-01-02 | 2024-01-24 | 2024-01-02 | 2024-01-24 | 20d | 0d | 0% |
| 711 | 1.2.6.2.3.1.5 | Tower (Level 3A) | 20d | 2024-01-02 | 2024-01-24 | 2024-01-02 | 2024-01-24 | 20d | 0d | 0% |
| 712 | 1.2.6.2.3.1.6 | Tower (Level 5) | 20d | 2024-01-02 | 2024-01-24 | 2024-01-02 | 2024-01-24 | 20d | 0d | 0% |
| 713 | 1.2.6.2.3.1.7 | Tower (Level 6) | 20d | 2024-01-02 | 2024-01-24 | 2024-01-02 | 2024-01-24 | 20d | 0d | 0% |
| 714 | 1.2.6.2.3.1.8 | Tower (Level 7) | 20d | 2024-01-02 | 2024-01-24 | 2024-01-02 | 2024-01-24 | 20d | 0d | 0% |
| 715 | 1.2.6.2.3.1.9 | Roof & LMR | 20d | 2024-01-02 | 2024-01-24 | 2024-01-02 | 2024-01-24 | 20d | 0d | 0% |
| 716 | 1.2.6.2.4 | **Installation Pump Panel & Calibrate with Pumps** | 14d | 2024-01-02 | 2024-01-17 |  |  |  | 0d | 0% |
| 717 | 1.2.6.2.4.1 | Cold Water Pump Room | 14d | 2024-01-02 | 2024-01-17 | 2024-01-02 | 2024-01-17 | 14d | 0d | 0% |
| 718 | 1.2.6.3 | **ACMV Services** | 20d | 2024-01-02 | 2024-01-24 |  |  |  | 0d | 0% |
| 719 | 1.2.6.3.1 | **1st Fix- Fan Opening Sleeve** | 20d | 2024-01-02 | 2024-01-24 |  |  |  | 0d | 0% |
| 720 | 1.2.6.3.1.1 | Podium (Ground Floor) | 20d | 2024-01-02 | 2024-01-24 | 2024-01-02 | 2024-01-24 | 20d | 0d | 0% |
| 721 | 1.2.6.3.1.2 | Podium (Level 1) | 20d | 2024-01-02 | 2024-01-24 | 2024-01-02 | 2024-01-24 | 20d | 0d | 0% |
| 722 | 1.2.6.3.1.3 | Podium (Level 2) | 20d | 2024-01-02 | 2024-01-24 | 2024-01-02 | 2024-01-24 | 20d | 0d | 0% |
| 723 | 1.2.6.3.1.4 | Podium (Level 3) | 20d | 2024-01-02 | 2024-01-24 | 2024-01-02 | 2024-01-24 | 20d | 0d | 0% |
| 724 | 1.2.6.3.1.5 | Tower (Level 3A) | 20d | 2024-01-02 | 2024-01-24 | 2024-01-02 | 2024-01-24 | 20d | 0d | 0% |
| 725 | 1.2.6.3.1.6 | Tower (Level 5) | 20d | 2024-01-02 | 2024-01-24 | 2024-01-02 | 2024-01-24 | 20d | 0d | 0% |
| 726 | 1.2.6.3.1.7 | Tower (Level 6) | 20d | 2024-01-02 | 2024-01-24 | 2024-01-02 | 2024-01-24 | 20d | 0d | 0% |
| 727 | 1.2.6.3.1.8 | Tower (Level 7) | 20d | 2024-01-02 | 2024-01-24 | 2024-01-02 | 2024-01-24 | 20d | 0d | 0% |
| 728 | 1.2.6.3.1.9 | Roof & LMR | 20d | 2024-01-02 | 2024-01-24 | 2024-01-02 | 2024-01-24 | 20d | 0d | 0% |

| ID | WBS | Task | Duration | Start | Finish | Baseline start | Baseline finish | Baseline duration | Total slack | Constraint | %Planned |
| --- | --- | --- | --- | --- | --- | --- | --- | --- | --- | --- | --- |
| 729 | 1.2.6.3.2 | **2nd Fix-Exhaust ducts,Wiring ,Drain Pipe & Copper Pipe** | 20d | 2024-01-02 | 2024-01-24 |  |  |  | 0d |  | 0% |
| 730 | 1.2.6.3.2.1 | Podium (Ground Floor) | 20d | 2024-01-02 | 2024-01-24 | 2024-01-02 | 2024-01-24 | 20d | 0d |  | 0% |
| 731 | 1.2.6.3.2.2 | Podium (Level 1) | 20d | 2024-01-02 | 2024-01-24 | 2024-01-02 | 2024-01-24 | 20d | 0d |  | 0% |
| 732 | 1.2.6.3.2.3 | Podium (Level 2) | 20d | 2024-01-02 | 2024-01-24 | 2024-01-02 | 2024-01-24 | 20d | 0d |  | 0% |
| 733 | 1.2.6.3.2.4 | Podium (Level 3) | 20d | 2024-01-02 | 2024-01-24 | 2024-01-02 | 2024-01-24 | 20d | 0d |  | 0% |
| 734 | 1.2.6.3.2.5 | Tower (Level 3A) | 20d | 2024-01-02 | 2024-01-24 | 2024-01-02 | 2024-01-24 | 20d | 0d |  | 0% |
| 735 | 1.2.6.3.2.6 | Tower (Level 5) | 20d | 2024-01-02 | 2024-01-24 | 2024-01-02 | 2024-01-24 | 20d | 0d |  | 0% |
| 736 | 1.2.6.3.2.7 | Tower (Level 6) | 20d | 2024-01-02 | 2024-01-24 | 2024-01-02 | 2024-01-24 | 20d | 0d |  | 0% |
| 737 | 1.2.6.3.2.8 | Tower (Level 7) | 20d | 2024-01-02 | 2024-01-24 | 2024-01-02 | 2024-01-24 | 20d | 0d |  | 0% |
| 738 | 1.2.6.3.2.9 | Roof & LMR | 20d | 2024-01-02 | 2024-01-24 | 2024-01-02 | 2024-01-24 | 20d | 0d |  | 0% |
| 739 | 1.2.6.3.3 | **Final Fix-Indoor & Outdoor & Grilles and Lourves** | 20d | 2024-01-02 | 2024-01-24 |  |  |  | 0d |  | 0% |
| 740 | 1.2.6.3.3.1 | Podium (Ground Floor) | 20d | 2024-01-02 | 2024-01-24 | 2024-01-02 | 2024-01-24 | 20d | 0d |  | 0% |
| 741 | 1.2.6.3.3.2 | Podium (Level 1) | 20d | 2024-01-02 | 2024-01-24 | 2024-01-02 | 2024-01-24 | 20d | 0d |  | 0% |
| 742 | 1.2.6.3.3.3 | Podium (Level 2) | 20d | 2024-01-02 | 2024-01-24 | 2024-01-02 | 2024-01-24 | 20d | 0d |  | 0% |
| 743 | 1.2.6.3.3.4 | Podium (Level 3) | 20d | 2024-01-02 | 2024-01-24 | 2024-01-02 | 2024-01-24 | 20d | 0d |  | 0% |
| 744 | 1.2.6.3.3.5 | Tower (Level 3A) | 20d | 2024-01-02 | 2024-01-24 | 2024-01-02 | 2024-01-24 | 20d | 0d |  | 0% |
| 745 | 1.2.6.3.3.6 | Tower (Level 5) | 20d | 2024-01-02 | 2024-01-24 | 2024-01-02 | 2024-01-24 | 20d | 0d |  | 0% |
| 746 | 1.2.6.3.3.7 | Tower (Level 6) | 20d | 2024-01-02 | 2024-01-24 | 2024-01-02 | 2024-01-24 | 20d | 0d |  | 0% |
| 747 | 1.2.6.3.3.8 | Tower (Level 7) | 20d | 2024-01-02 | 2024-01-24 | 2024-01-02 | 2024-01-24 | 20d | 0d |  | 0% |
| 748 | 1.2.6.3.3.9 | Roof & LMR | 20d | 2024-01-02 | 2024-01-24 | 2024-01-02 | 2024-01-24 | 20d | 0d |  | 0% |
| 749 | 1.2.6.4 | **Fire Protection Services** | 30d | 2024-01-02 | 2024-02-05 |  |  |  | 0d |  | 0% |
| 750 | 1.2.6.4.1 | **1st Fix- Fire Protection -Concealed Pipe Sleeve Installation** | 20d | 2024-01-02 | 2024-01-24 |  |  |  | 0d |  | 0% |
| 751 | 1.2.6.4.1.1 | Podium (Ground Floor) | 20d | 2024-01-02 | 2024-01-24 | 2024-01-02 | 2024-01-24 | 20d | 0d |  | 0% |
| 752 | 1.2.6.4.1.2 | Podium (Level 1) | 20d | 2024-01-02 | 2024-01-24 | 2024-01-02 | 2024-01-24 | 20d | 0d |  | 0% |
| 753 | 1.2.6.4.1.3 | Podium (Level 2) | 20d | 2024-01-02 | 2024-01-24 | 2024-01-02 | 2024-01-24 | 20d | 0d |  | 0% |
| 754 | 1.2.6.4.1.4 | Podium (Level 3) | 20d | 2024-01-02 | 2024-01-24 | 2024-01-02 | 2024-01-24 | 20d | 0d |  | 0% |
| 755 | 1.2.6.4.1.5 | Tower (Level 3A) | 20d | 2024-01-02 | 2024-01-24 | 2024-01-02 | 2024-01-24 | 20d | 0d |  | 0% |
| 756 | 1.2.6.4.1.6 | Tower (Level 5) | 20d | 2024-01-02 | 2024-01-24 | 2024-01-02 | 2024-01-24 | 20d | 0d |  | 0% |
| 757 | 1.2.6.4.1.7 | Tower (Level 6) | 20d | 2024-01-02 | 2024-01-24 | 2024-01-02 | 2024-01-24 | 20d | 0d |  | 0% |
| 758 | 1.2.6.4.1.8 | Tower (Level 7) | 20d | 2024-01-02 | 2024-01-24 | 2024-01-02 | 2024-01-24 | 20d | 0d |  | 0% |
| 759 | 1.2.6.4.1.9 | Roof & LMR | 20d | 2024-01-02 | 2024-01-24 | 2024-01-02 | 2024-01-24 | 20d | 0d | finish no earlier than 2024-01-24 | 0% |

| ID | WBS | Task | Duration | Start | Finish | Baseline start | Baseline finish | Baseline duration | Total slack | %Planned |
| --- | --- | --- | --- | --- | --- | --- | --- | --- | --- | --- |
| 760 | 1.2.6.4.2 | **2nd Fix - Fire Protection - Installation Sprinkler Pipe, Hose Reel Pipe Fitting, Fire Alarm Wiring & Wet Riser Pipe Fitting** | 20d | 2024-01-02 | 2024-01-24 |  |  |  | 0d | 0% |
| 761 | 1.2.6.4.2.1 | Podium (Ground Floor) | 20d | 2024-01-02 | 2024-01-24 | 2024-01-02 | 2024-01-24 | 20d | 0d | 0% |
| 762 | 1.2.6.4.2.2 | Podium (Level 1) | 20d | 2024-01-02 | 2024-01-24 | 2024-01-02 | 2024-01-24 | 20d | 0d | 0% |
| 763 | 1.2.6.4.2.3 | Podium (Level 2) | 20d | 2024-01-02 | 2024-01-24 | 2024-01-02 | 2024-01-24 | 20d | 0d | 0% |
| 764 | 1.2.6.4.2.4 | Podium (Level 3) | 20d | 2024-01-02 | 2024-01-24 | 2024-01-02 | 2024-01-24 | 20d | 0d | 0% |
| 765 | 1.2.6.4.2.5 | Tower (Level 3A) | 20d | 2024-01-02 | 2024-01-24 | 2024-01-02 | 2024-01-24 | 20d | 0d | 0% |
| 766 | 1.2.6.4.2.6 | Tower (Level 5) | 20d | 2024-01-02 | 2024-01-24 | 2024-01-02 | 2024-01-24 | 20d | 0d | 0% |
| 767 | 1.2.6.4.2.7 | Tower (Level 6) | 20d | 2024-01-02 | 2024-01-24 | 2024-01-02 | 2024-01-24 | 20d | 0d | 0% |
| 768 | 1.2.6.4.2.8 | Tower (Level 7) | 20d | 2024-01-02 | 2024-01-24 | 2024-01-02 | 2024-01-24 | 20d | 0d | 0% |
| 769 | 1.2.6.4.2.9 | Roof & LMR | 20d | 2024-01-02 | 2024-01-24 | 2024-01-02 | 2024-01-24 | 20d | 0d | 0% |
| 770 | 1.2.6.4.3 | **Final Fix - Fire Protection -Installation of Sprinkler Head & Hose Reel Drum, Panel & Fire Intercom, Fire Alarm Devices & Wet Riser Landing Valve** | 30d | 2024-01-02 | 2024-02-05 |  |  |  | 0d | 0% |
| 771 | 1.2.6.4.3.1 | Podium (Ground Floor) | 20d | 2024-01-02 | 2024-01-24 | 2024-01-02 | 2024-01-24 | 20d | 0d | 0% |
| 772 | 1.2.6.4.3.2 | Podium (Level 1) | 20d | 2024-01-02 | 2024-01-24 | 2024-01-02 | 2024-01-24 | 20d | 0d | 0% |
| 773 | 1.2.6.4.3.3 | Podium (Level 2) | 20d | 2024-01-02 | 2024-01-24 | 2024-01-02 | 2024-01-24 | 20d | 0d | 0% |
| 774 | 1.2.6.4.3.4 | Podium (Level 3) | 20d | 2024-01-02 | 2024-01-24 | 2024-01-02 | 2024-01-24 | 20d | 0d | 0% |
| 775 | 1.2.6.4.3.5 | Tower (Level 3A) | 20d | 2024-01-02 | 2024-01-24 | 2024-01-02 | 2024-01-24 | 20d | 0d | 0% |
| 776 | 1.2.6.4.3.6 | Tower (Level 5) | 20d | 2024-01-02 | 2024-01-24 | 2024-01-02 | 2024-01-24 | 20d | 0d | 0% |
| 777 | 1.2.6.4.3.7 | Tower (Level 6) | 20d | 2024-01-02 | 2024-01-24 | 2024-01-02 | 2024-01-24 | 20d | 0d | 0% |
| 778 | 1.2.6.4.3.8 | Tower (Level 7) | 20d | 2024-01-02 | 2024-01-24 | 2024-01-02 | 2024-01-24 | 20d | 0d | 0% |
| 779 | 1.2.6.4.3.9 | Roof & LMR | 20d | 2024-01-02 | 2024-01-24 | 2024-01-02 | 2024-01-24 | 20d | 0d | 0% |
| 780 | 1.2.6.4.3.10 | Hyrant Pipe & Pillar Installation | 30d | 2024-01-02 | 2024-02-05 | 2024-01-02 | 2024-02-05 | 30d | 0d | 0% |
| 781 | 1.2.6.4.4 | **Installation Pump Panel & Calibrate with Pumps** | 30d | 2024-01-02 | 2024-02-05 |  |  |  | 0d | 0% |
| 782 | 1.2.6.4.4.1 | Sprinkler Tank | 30d | 2024-01-02 | 2024-02-05 | 2024-01-02 | 2024-02-05 | 30d | 0d | 0% |
| 783 | 1.2.6.4.4.2 | Hose Reel Tank | 30d | 2024-01-02 | 2024-02-05 | 2024-01-02 | 2024-02-05 | 30d | 0d | 0% |

| ID | WBS | Task | Duration | Start | Finish | Baseline start | Baseline finish | Baseline duration | Total slack | Constraint | %Planned |
| --- | --- | --- | --- | --- | --- | --- | --- | --- | --- | --- | --- |
| 784 | 1.2.6.5 | **Lift & Goods Hoist Services** | 180d | 2024-01-02 | 2024-08-05 |  |  |  | 0d |  | 0% |
| 785 | 1.2.6.5.1 | Bracket Guard Rail & Door Jamb | 180d | 2024-01-02 | 2024-08-05 |  |  |  | 0d |  | 0% |
| 786 | 1.2.6.5.2 | Lift Car, Motor & Cabling | 180d | 2024-01-02 | 2024-08-05 |  |  |  | 0d |  | 0% |
| 787 | 1.2.6.5.3 | T&C Works, Low Speed, High Speed Homing | 100d | 2024-01-02 | 2024-04-29 |  |  |  | 0d |  | 0% |
| 788 | 1.2.7 | **TNB Substation** | 20d | 2024-01-02 | 2024-01-24 |  |  |  | 0d |  | 0% |
| 789 | 1.2.7.1 | **Structure** | 20d | 2024-01-02 | 2024-01-24 |  |  |  | 0d |  | 0% |
| 790 | 1.2.7.1.1 | Piling & Pile Cap | 14d | 2024-01-02 | 2024-01-17 | 2024-01-02 | 2024-01-17 | 14d | 0d |  | 0% |
| 791 | 1.2.7.1.2 | Beam, Slab & Column | 20d | 2024-01-02 | 2024-01-24 | 2024-01-02 | 2024-01-24 | 20d | 0d | start no earlier than 2024-01-02 | 0% |
| 792 | 1.2.7.1.3 | Roof Beam & Slab | 20d | 2024-01-02 | 2024-01-24 | 2024-01-02 | 2024-01-24 | 20d | 0d |  | 0% |
| 793 | 1.2.7.1.4 | Apron Slab and Ramp | 14d | 2024-01-02 | 2024-01-17 | 2024-01-02 | 2024-01-17 | 14d | 0d |  | 0% |
| 794 | 1.2.7.2 | **Architecture** | 20d | 2024-01-02 | 2024-01-24 |  |  |  | 0d |  | 0% |
| 795 | 1.2.7.2.1 | Brick Work & Door Frame | 14d | 2024-01-02 | 2024-01-17 | 2024-01-02 | 2024-01-17 | 14d | 0d |  | 0% |
| 796 | 1.2.7.2.2 | Plaster | 14d | 2024-01-02 | 2024-01-17 | 2024-01-02 | 2024-01-17 | 14d | 0d |  | 0% |
| 797 | 1.2.7.2.3 | Waterproofing | 7d | 2024-01-02 | 2024-01-09 | 2024-01-02 | 2024-01-09 | 7d | 0d |  | 0% |
| 798 | 1.2.7.2.4 | External Plaster & Painting | 20d | 2024-01-02 | 2024-01-24 | 2024-01-02 | 2024-01-24 | 20d | 0d |  | 0% |
| 799 | 1.2.7.2.5 | Door Leaves and Ironmongeries | 7d | 2024-01-02 | 2024-01-09 | 2024-01-02 | 2024-01-09 | 7d | 0d |  | 0% |
| 800 | 1.2.7.2.6 | Flooring Expoxy | 7d | 2024-01-02 | 2024-01-09 | 2024-01-02 | 2024-01-09 | 7d | 0d |  | 0% |
| 801 | 1.2.7.3 | **M&E** | 14d | 2024-01-02 | 2024-01-17 |  |  |  | 0d |  | 0% |
| 802 | 1.2.7.3.1 | TNB Room -Lighting & Power | 14d | 2024-01-02 | 2024-01-17 | 2024-01-02 | 2024-01-17 | 14d | 0d |  | 0% |
| 803 | 1.2.7.3.2 | TNB Room - Electrical Distribution Board | 14d | 2024-01-02 | 2024-01-17 | 2024-01-02 | 2024-01-17 | 14d | 0d |  | 0% |
| 804 | 1.2.7.3.3 | TNB Room - Laid Cabling & Connection to Existing | 14d | 2024-01-02 | 2024-01-17 | 2024-01-02 | 2024-01-17 | 14d | 0d |  | 0% |
| 805 | 1.2.7.3.4 | TNB Room - Earthing system | 14d | 2024-01-02 | 2024-01-17 | 2024-01-02 | 2024-01-17 | 14d | 0d |  | 0% |
| 806 | 1.2.8 | **Guard House** | 20d | 2024-01-02 | 2024-01-24 |  |  |  | 0d |  | 0% |
| 807 | 1.2.8.1 | **Structure** | 14d | 2024-01-02 | 2024-01-17 |  |  |  | 0d |  | 0% |
| 808 | 1.2.8.1.1 | Piling & Pile Cap | 14d | 2024-01-02 | 2024-01-17 | 2024-01-02 | 2024-01-17 | 14d | 0d |  | 0% |
| 809 | 1.2.8.1.2 | Beam, Slab & Column | 14d | 2024-01-02 | 2024-01-17 | 2024-01-02 | 2024-01-17 | 14d | 0d |  | 0% |
| 810 | 1.2.8.1.3 | Roof Beam & Slab | 14d | 2024-01-02 | 2024-01-17 | 2024-01-02 | 2024-01-17 | 14d | 0d |  | 0% |

| ID | WBS | Task | Type | Duration | Start | Finish | Baseline start | Baseline finish | Baseline duration | Total slack | %Planned |
| --- | --- | --- | --- | --- | --- | --- | --- | --- | --- | --- | --- |
| 811 | 1.2.8.2 | **Architecture** |  | 20d | 2024-01-02 | 2024-01-24 |  |  |  | 0d | 0% |
| 812 | 1.2.8.2.1 | Brick Work & Door Frame |  | 20d | 2024-01-02 | 2024-01-24 | 2024-01-02 | 2024-01-24 | 20d | 0d | 0% |
| 813 | 1.2.8.2.2 | Plaster |  | 14d | 2024-01-02 | 2024-01-17 | 2024-01-02 | 2024-01-17 | 14d | 0d | 0% |
| 814 | 1.2.8.2.3 | Window Frame |  | 7d | 2024-01-02 | 2024-01-09 | 2024-01-02 | 2024-01-09 | 7d | 0d | 0% |
| 815 | 1.2.8.2.4 | Waterproofing & RWDP |  | 7d | 2024-01-02 | 2024-01-09 | 2024-01-02 | 2024-01-09 | 7d | 0d | 0% |
| 816 | 1.2.8.2.5 | Screeding & Tiles |  | 14d | 2024-01-02 | 2024-01-17 | 2024-01-02 | 2024-01-17 | 14d | 0d | 0% |
| 817 | 1.2.8.2.6 | Ceiling |  | 14d | 2024-01-02 | 2024-01-17 | 2024-01-02 | 2024-01-17 | 14d | 0d | 0% |
| 818 | 1.2.8.2.7 | Window Glazing |  | 7d | 2024-01-02 | 2024-01-09 | 2024-01-02 | 2024-01-09 | 7d | 0d | 0% |
| 819 | 1.2.8.2.8 | External Plaster & Painting |  | 14d | 2024-01-02 | 2024-01-17 | 2024-01-02 | 2024-01-17 | 14d | 0d | 0% |
| 820 | 1.2.8.2.9 | Sanitary & Fitting |  | 7d | 2024-01-02 | 2024-01-09 | 2024-01-02 | 2024-01-09 | 7d | 0d | 0% |
| 821 | 1.2.8.2.10 | Door Leaves and Ironmongeries |  | 7d | 2024-01-02 | 2024-01-09 | 2024-01-02 | 2024-01-09 | 7d | 0d | 0% |
| 822 | 1.2.9 | Landscape |  | 60d | 2024-01-02 | 2024-03-11 |  |  |  | 0d | 0% |
| 823 | 1.2.10 | **External Work** |  | 90d | 2024-01-02 | 2024-04-17 |  |  |  | 0d | 0% |
| 824 | 1.2.10.1 | Sewerage |  | 90d | 2024-01-02 | 2024-04-17 |  |  |  | 0d | 0% |
| 825 | 1.2.10.2 | Water Reticulation |  | 60d | 2024-01-02 | 2024-03-11 |  |  |  | 0d | 0% |
| 826 | 1.2.10.3 | Drainage |  | 90d | 2024-01-02 | 2024-04-17 |  |  |  | 0d | 0% |
| 827 | 1.2.10.4 | Concrete Paver Drive Way |  | 50d | 2024-01-02 | 2024-02-28 |  |  |  | 0d | 0% |
| 828 | 1.2.10.5 | Premix Driveway |  | 60d | 2024-01-02 | 2024-03-11 |  |  |  | 0d | 0% |
| 829 | 1.2.10.6 | Road and Road Kerb |  | 90d | 2024-01-02 | 2024-04-17 |  |  |  | 0d | 0% |
| 830 | 1.2.10.7 | Road Marking & Road Signage |  | 30d | 2024-01-02 | 2024-02-05 |  |  |  | 0d | 0% |
| 831 | 1.2.10.8 | Fencing and Gate |  | 60d | 2024-01-02 | 2024-03-11 |  |  |  | 0d | 0% |
| 832 | 1.2.11 | **T&C** |  | 60d | 2024-01-02 | 2024-03-11 |  |  |  | 0d | 0% |
| 833 | 1.2.11.1 | Testing & Commisioning |  | 60d | 2024-01-02 | 2024-03-11 |  |  |  | 0d | 0% |
| 834 | 1.2.12 | **Authority Inspection** |  | 30d | 2024-01-02 | 2024-02-05 |  |  |  | 0d | 0% |
| 835 | 1.2.12.1 | IWK Inspection |  | 30d | 2024-01-02 | 2024-02-05 |  |  |  | 0d | 0% |
| 836 | 1.2.12.2 | JKKP inspection |  | 30d | 2024-01-02 | 2024-02-05 |  |  |  | 0d | 0% |
| 837 | 1.2.12.3 | Pre-Bomba Inspection |  | 14d | 2024-01-02 | 2024-01-17 |  |  |  | 0d | 0% |
| 838 | 1.2.12.4 | Bomba Inspection |  | 14d | 2024-01-02 | 2024-01-17 |  |  |  | 0d | 0% |
| 839 | 1.2.12.5 | Landscape Inspection | manual | 14d | 2024-01-02 | 2024-01-17 |  |  |  |  | 0% |
| 840 | 1.2.12.6 | Building Inspection |  | 14d | 2024-01-02 | 2024-01-17 |  |  |  | 0d | 0% |
| 841 | 1.2.13 | Handover & Completion & CPC |  | 1d | 2024-01-02 | 2024-01-02 |  |  |  | 0d | 0% |
